# AIP Cryo April 1

Schedule from MS Project, 2013-06-03 to 2017-07-28, status date 2017-02-28, costs in $, A marks actual dates.
Fermilab

## Calendars

- Standard: Mon-Fri 08:00-12:00, 13:00-17:00; Sat-Sun off. Exceptions (off unless hours are given): 2013-07-04 (Independence Day), 2013-09-02 (Labor Day), 2013-11-28 to 2013-11-29 (Thanksgiving), 2013-12-24 to 2013-12-25 (Christmas), 2013-12-31 to 2014-01-01 (New Years), 2014-01-20 (Martin Luther King Day), 2014-05-26 (Memorial Day), 2014-07-04 (Independence Day), 2014-09-01 (Labor Day), 2014-11-27 to 2014-11-28 (Thanksgiving), 2014-12-24 to 2014-12-25 (Christmas), 2014-12-31 to 2015-01-01 (New Years), 2015-01-19 (Martin Luther King Day), 2015-05-25 (Memorial Day), 2015-07-03 (Independence Day), 2015-09-07 to 2015-09-08 (Labor Day), 2015-11-26 to 2015-11-27 (Thanksgiving), 2015-12-24 to 2015-12-25 (Christmas), 2015-12-31 to 2016-01-01 (New Years), 2016-01-18 (Martin Luther King Day), 2016-05-30 (Memorial Day), 2016-07-04 (Independence Day), 2016-09-05 (Labor Day), 2016-11-24 to 2016-11-25 (Thanksgiving), 2016-12-23 to 2016-12-26 (Christmas), 2016-12-30 to 2017-01-02 (New Years), 2017-01-16 (Martin Luther King Day), 2017-05-29 (Memorial Day), 2017-07-04 (Independence Day).

## Resources

| Resource | Group | Rate |
| --- | --- | --- |
| FNAD_CRYO_EN | AD | 42.94 |
| FNAD_CRYO_TECH | AD | 30.89 |
| FNAD_CRYO_SR | AD | 59.74 |
| FNAD_MECH_DRAFTER | AD | 28.88 |
| FNAD_PRJ_CTRL_MNGR | AD | 72 |
| FN_MS_STND_FY13 |  |  |
| FN_MS_EXMP_FY13 |  |  |
| FNPD_CRYO_SR | PD | 59.74 |
| FNTD_CRYO_DESIGNER | TD | 34.54 |
| FNTD_MECH_DESIGNER | TD | 36.2 |
| FNTD_CRYO_EN | TD | 42.94 |
| FNTD_FABRCATN_SPCLST | TD | 40.32 |
| FNAD_MECH_ASMBY_TECH | AD | 30.44 |
| FNTD_PRJ_MNGR | TD | 58.55 |
| FNTD_WELDER | OT | 79 |
| FNAD_AC_EXP_PHYST | AD | 54.33 |
| FNTD_MECH_DESIGN_EN | TD | 50.54 |
| FNPD_CRYO_EN | PD | 42.94 |
| FNPD_CRYO_TECH | PD | 30.89 |
| FNPD_MECH_ASMBY_TECH | PD | 30.44 |
| FNTD_MECH_ASMBY_TECH | TD | 30.44 |
| FNTD_CRYO_TECH | TD | 30.44 |

## Schedule

| ID | WBS | Task | Type | Duration | Start | Finish | Predecessors | Complete | Remaining | Baseline start | Baseline finish | Baseline duration | Total slack | Free slack | Constraint | Work | Actual work | Cost | Baseline cost | Actual cost | Cobra WBS # | Text20 | CR# |
| --- | --- | --- | --- | --- | --- | --- | --- | --- | --- | --- | --- | --- | --- | --- | --- | --- | --- | --- | --- | --- | --- | --- | --- |
| 1 | Cryo1 | **Muon Campus Cryogenics - AIP** |  | 1043d | 2013-06-03 A | 2017-07-28 |  | 93% | 70.66d | 2013-06-03 | 2017-09-29 | 1018d | 0d |  |  | 37288h | 34187.6h | 4,961,321.39 | 3,791,947.75 | 4,395,506.47 | Cryo1 |  |  |
| 2 | Cryo1.01 | **Cryo AIP Milestones** |  | 1043d | 2013-06-03 A | 2017-07-28 |  | 33% | 695.33d | 2013-06-03 | 2017-09-29 | 1018d | 0d |  |  |  |  |  |  |  | Cryo1.01 |  |  |
| 3 | Cryo1.01.01 | **Cryo AIP Management Milestones** |  | 1018d | 2013-06-03 A | 2017-06-22 |  | 99% | 0d | 2013-06-03 | 2017-06-22 | 1018d | 25d |  |  |  |  |  |  |  |  |  |  |
| 4 | Cryo1.01.01.01 | FY13 funding | milestone | 0d | 2013-06-03 A | 2013-06-03 A |  | 100% |  | 2013-06-03 | 2013-06-03 | 0d |  |  | start no earlier than 2013-06-03 |  |  |  |  |  |  |  |  |
| 5 | Cryo1.01.01.02 | FY14 funding | milestone | 0d | 2013-10-01 A | 2013-10-01 A |  | 100% |  | 2013-10-01 | 2013-10-01 | 0d |  |  | start no earlier than 2013-10-01 |  |  |  |  |  |  |  |  |
| 6 | Cryo1.01.01.03 | FY15 funding | milestone | 0d | 2014-10-01 A | 2014-10-01 A |  | 100% |  | 2014-10-01 | 2014-10-01 | 0d |  |  | start no earlier than 2014-10-01 |  |  |  |  |  |  |  |  |
| 7 | Cryo1.01.01.06 | Finish Cryo AIP Project | milestone | 0d | 2017-06-22 | 2017-06-22 | 37, 161 |  |  | 2017-06-22 | 2017-06-22 | 0d | 25d | 23d |  |  |  |  |  |  |  |  |  |
| 8 | Cryo1.01.01.07 | FY16 Funding | milestone | 0d | 2015-10-01 A | 2015-10-01 A |  | 100% |  | 2015-10-01 | 2015-10-01 | 0d |  |  | start no earlier than 2015-10-01 |  |  |  |  |  |  |  |  |
| 9 | Cryo1.01.01.08 | FY17 Funding | milestone | 0d | 2016-10-03 A | 2016-10-03 A |  | 100% |  | 2016-10-03 | 2016-10-03 | 0d |  |  | start no earlier than 2016-10-03 |  |  |  |  |  |  |  |  |
| 10 | Cryo1.01.01.09 | g-2 Cold (g-2 Interface) - Target |  | 1d | 2015-01-02 A | 2015-01-02 A | 76, 93, 97, 106FS+20d, 114, 169, 83, 175, 216, 296, 297, 42, 26, 188, 251 | 100% |  | 2015-01-02 | 2015-01-02 | 0d |  |  | finish no later than 2015-01-02 |  |  |  |  |  |  |  |  |
| 11 | Cryo1.01.01.09 | System Engineering Complete | milestone | 0d | 2015-03-02 A | 2015-03-02 A |  | 100% |  | 2017-05-26 | 2017-05-26 | 0d |  |  | start no earlier than 2015-03-02 |  |  |  |  |  |  |  |  |
| 12 | Cryo1.01.02 | **Interface milestones** |  | 894d | 2014-01-08 A | 2017-07-28 |  |  | 894d | 2014-01-08 | 2017-07-15 | 847d | 0d |  |  |  |  |  |  |  |  |  |  |
| 13 | Cryo1.01.02.01 | MC-1 Bldg Beneficial Occupancy for Cryo (MC-1 Building GPP Interface) | milestone | 0d | 2014-01-08 A | 2014-01-08 A |  | 100% |  | 2014-01-08 | 2014-01-08 | 0d |  |  | start no earlier than 2014-01-08 |  |  |  |  |  |  | Do we have a target date for this? |  |
| 14 | Cryo1.01.02.02 | A0 to MC1 Header Supports Ready (MC-1 Building GPP Interface) | milestone | 0d | 2014-01-08 A | 2014-01-08 A | 13 | 100% |  | 2014-01-08 | 2014-01-08 | 0d |  |  | start no earlier than 2014-01-08 |  |  |  |  |  |  | Need successor, any other predecessors? |  |
| 15 | Cryo1.01.02.03 | High Bay Beneficial Occupancy | milestone | 0d | 2014-04-10 A | 2014-04-10 A |  | 100% |  | 2014-04-15 | 2014-04-15 | 0d |  |  | start no earlier than 2014-04-10 |  |  |  |  |  |  |  |  |
| 16 | Cryo1.01.02.04 | Cryo Ready to Cool g-2 | milestone | 0d | 2015-02-20 A | 2015-02-20 A | 10FS+34d, 79 | 100% |  | 2015-02-20 | 2015-02-20 | 0d |  |  | finish no later than 2015-03-15 |  |  |  |  |  |  |  |  |
| 17 | Cryo1.01.02.05 | Cryo Mu2e Distribution Box Cold (Mu2e Interface) | milestone | 0d | 2017-07-28 | 2017-07-28 | 244, 250, 298 |  |  | 2017-07-15 | 2017-07-15 | 0d | 0d |  | finish no later than 2017-09-15 |  |  |  |  |  |  |  | CR013 |
| 18 | Cryo1.01.02.06 | MC-1 Cryo Controls Room Available | milestone | 0d | 2014-09-22 A | 2014-09-22 A |  | 100% |  | 2014-09-22 | 2014-09-22 | 0d |  |  | start no earlier than 2014-09-22 |  |  |  |  |  |  |  |  |
| 19 | Cryo1.01.02.07 | Cryo Compressor Cooling Established | milestone | 0d | 2014-06-02 A | 2014-06-02 A | 175FF+2d | 100% |  | 2014-09-23 | 2014-09-23 | 0d |  |  | finish no later than 2014-09-30 |  |  |  |  |  |  |  |  |
| 20 | Cryo1.01.02.08 | Mu2e Bldg Completed | milestone | 0d | 2016-11-11 A | 2016-11-11 A |  | 100% |  | 2016-06-01 | 2016-06-01 | 0d |  |  | start no earlier than 2016-11-11 |  |  |  |  |  |  |  | CR013 |
| 21 | Cryo1.01.03 | **Project Plan Milestones** |  | 1030d | 2013-06-17 A | 2017-07-25 |  |  | 1030d | 2013-06-17 | 2017-09-29 | 745d | 3d |  |  |  |  |  |  |  |  |  |  |
| 22 | Cryo1.01.03.01 | Start of Cryo AIP Project | milestone | 0d | 2013-06-17 A | 2013-06-17 A | 4 | 100% |  | 2013-06-17 | 2013-06-17 | 0d |  |  | start no earlier than 2013-06-17 |  |  |  |  |  |  |  |  |
| 23 | Cryo1.01.03.02 | Start Refrigeration Bldg Installation | milestone | 0d | 2014-01-03 A | 2014-01-03 A |  | 100% |  | 2014-01-03 | 2014-01-03 | 0d |  |  | start no earlier than 2014-01-03 |  |  |  |  |  |  |  |  |
| 24 | Cryo1.01.03.03 | Compressor System Ready | milestone | 0d | 2014-09-15 A | 2014-09-15 A | 186, 177, 179 | 100% |  | 2014-09-15 | 2014-09-15 | 0d |  |  | start no earlier than 2014-09-15 |  |  |  |  |  |  |  |  |
| 25 | Cryo1.01.03.04 | Refrigeration System Commissioned | milestone | 0d | 2015-02-16 A | 2015-02-16 A | 120, 106FS+15d | 100% |  | 2015-02-16 | 2015-02-16 | 0d |  |  | start no earlier than 2015-02-16 |  |  |  |  |  |  |  |  |
| 26 | Cryo1.01.03.05 | Muon g-2 Acceptance Tests Complete | milestone | 0d | 2014-10-20 A | 2014-10-20 A | 24, 297FS-10d | 100% |  | 2015-03-16 | 2015-03-16 | 0d |  |  | start no earlier than 2014-10-20 |  |  |  |  |  |  |  |  |
| 27 | Cryo1.01.03.07 | Transfer Line MC1 - MC2 Installed |  | 1d | 2017-06-02 | 2017-06-02 | 244, 241 |  |  | 2017-01-31 | 2017-01-31 | 0d | 39d | 36d |  |  |  |  |  |  |  |  |  |
| 28 | Cryo1.01.03.08 | Mu2e Cryo Distribution Box Delivered |  | 1d | 2017-07-25 | 2017-07-25 | 284 |  |  | 2017-06-30 | 2017-06-30 | 0d | 3d | 0d |  |  |  |  |  |  |  |  |  |
| 29 | Cryo1.01.03.09 | Mu2e Acceptance Tests Complete | milestone | 0d | 2017-06-29 | 2017-06-29 | 254 |  |  | 2017-09-18 | 2017-09-18 | 0d | 20d |  |  |  |  |  |  |  |  |  |  |
| 30 | Cryo1.01.03.10 | Project Complete | milestone | 0d | 2017-07-25 | 2017-07-25 | 7, 221, 222, 28, 27 |  |  | 2017-09-29 | 2017-09-29 | 0d | 3d |  |  |  |  |  |  |  |  |  |  |

| ID | WBS | Task | Type | Duration | Start | Finish | Predecessors | Complete | Remaining | Baseline start | Baseline finish | Baseline duration | Total slack | Free slack | Constraint | Resources | Work | Actual work | Cost | Baseline cost | Actual cost | BOE File Name | BOE Number | Cobra WBS # | CTC + Name | Cobra WP ID | Text20 | CTC | Misc | CR# |
| --- | --- | --- | --- | --- | --- | --- | --- | --- | --- | --- | --- | --- | --- | --- | --- | --- | --- | --- | --- | --- | --- | --- | --- | --- | --- | --- | --- | --- | --- | --- |
| 31 | Cryo1.02 | **Cryo Project Management** |  | 1008d | 2013-06-17 A | 2017-06-22 |  | 93% | 68.78d | 2013-08-01 | 2017-06-22 | 1008d | 25d |  |  |  | 2654h | 2327.24h | 285,976.83 | 264,024.3 | 258,308.65 | +Cryo Project Management BOE | Beams 4395 | Cryo1.02 |  |  |  |  |  |  |
| 32 | Cryo1.02.01 | **General Project OS** |  | 1008d | 2013-06-17 A | 2017-06-22 |  | 93% | 68.78d | 2013-08-01 | 2017-06-22 | 1008d | 25d |  |  |  | 2654h | 2327.24h | 285,976.83 | 264,024.3 | 258,308.65 | +Cryo Project Management BOE | Beams 4395 | Cryo1.02.01 |  |  |  |  |  |  |
| 33 | Cryo1.02.01.01 | Cryo AIP General Project OS - FY13 |  | 68d | 2013-06-17 A | 2013-09-20 A | 22 | 100% |  | 2013-08-01 | 2013-09-20 | 68d |  |  | start no earlier than 2012-10-01 | FNAD_PRJ_CTRL_MNGR [15.1%]; FNAD_CRYO_EN [51.4%]; FNAD_CRYO_SR [3.6%]; FN_MS_STND_FY13 [500000%] | 266h | 266h | 19,486.42 | 19,485.82 | 19,486.42 | +Cryo Project Management BOE | Beams 4395 | Cryo1.02.01.01 | A1301.02.01.01 - Cryo AIP General Project OS - FY13 | 2361 | Need new start/predecessor | A1301.02.01.01 |  |  |
| 34 | Cryo1.02.01.02 | Cryo AIP General Project OS - FY14 |  | 251d | 2013-09-23 A | 2014-09-22 A | 33 | 100% |  | 2013-09-23 | 2014-09-22 | 251d |  |  |  | FNAD_CRYO_SR [11.9%]; FNAD_CRYO_EN [17.4%]; FN_MS_STND_FY13 | 588h | 588h | 63,378.39 | 68,729.1 | 63,378.39 | +Cryo Project Management BOE | Beams 4395 | Cryo1.02.01.02 | A1301.02.01.02 - Cryo AIP General Project OS - FY14 | 2755 |  | A1301.02.01.02 |  |  |
| 35 | Cryo1.02.01.03 | Cryo AIP General Project OS - FY15 |  | 250d | 2014-09-23 A | 2015-09-22 A | 34 | 100% |  | 2014-09-23 | 2015-09-22 | 250d |  |  |  | FNAD_CRYO_SR [1.2%]; FN_MS_STND_FY13 | 24h | 24h | 23,433.76 | 63,844.52 | 23,433.76 | +Cryo Project Management BOE | Beams 4395 | Cryo1.02.01.03 | A1301.02.01.03 - Cryo AIP General Project OS - FY15 | 2756 |  | A1301.02.01.03 | ***Charge Code*** | CR008 |
| 36 | Cryo1.02.01.04 | Cryo AIP General Project OS - FY16 |  | 252d | 2015-09-23 A | 2016-09-22 A | 35, 38 | 100% |  | 2015-09-23 | 2016-09-22 | 252d |  |  |  | FNPD_CRYO_SR [4.4%]; FNPD_CRYO_EN [17.4%]; FNTD_PRJ_MNGR [8.8%]; FNAD_AC_EXP_PHYST [5%]; FN_MS_STND_FY13 | 715h | 715h | 78,082.47 | 64,023.74 | 78,082.47 | +Cryo Project Management BOE | Beams 4395 | Cryo1.02.01.04 | A1301.02.01.04 - Cryo AIP General Project OS - FY16 | 2757 |  | A1301.02.01.04 |  | CR014 |
| 37 | Cryo1.02.01.05 | Cryo AIP General Project OS - FY17 |  | 187d | 2016-09-23 A | 2017-06-22 | 36 | 58% | 78.54d | 2016-09-23 | 2017-06-22 | 187d | 25d | 0d |  | FNPD_CRYO_SR [5.9%]; FNPD_CRYO_EN [23.4%]; FNTD_PRJ_MNGR [17.7%]; FNAD_AC_EXP_PHYST [5%]; FN_MS_STND_FY13 | 778h | 451.24h | 65,876.62 | 53,291.28 | 38,208.44 | +Cryo Project Management BOE | Beams 4395 | Cryo1.02.01.05 | A1301.02.01.05 - Cryo AIP General Project OS - FY17 | 2758 |  | A1301.02.01.05 |  | CR014 |
| 38 | Cryo1.02.01.07 | Cryo AIP General Project OS - FY15 Suppl |  | 143d | 2015-03-02 A | 2015-09-22 A |  | 100% |  | 2015-03-02 | 2015-09-22 | 0d |  |  | start no earlier than 2015-03-02 | FNPD_CRYO_SR [7.7%]; FNTD_PRJ_MNGR [11.8%]; FNAD_AC_EXP_PHYST [5.2%]; FN_MS_STND_FY13 | 283h | 283h | 35,719.17 |  | 35,719.17 |  |  | Cryo1.02.01.07 | A1301.02.01.07 - Cryo AIP General Project OS - FY15 Suppl | 2936 |  | A1301.02.01.07 |  | CR013 |
| 39 | Cryo1.03 | **Cryo Basic Engineering** |  | 427d | 2013-06-17 A | 2015-03-02 A |  | 100% |  | 2013-06-17 | 2015-03-31 | 990d |  |  |  |  | 2196h | 2196h | 86,327.41 | 151,595.89 | 86,327.41 | +Cryo Basic Engineering BOE | Beams 4395 | Cryo1.03 |  |  |  |  |  |  |
| 40 | Cryo1.03.01 | Basic Engineering Prel Work |  | 20d | 2013-06-17 A | 2013-07-15 A | 22 | 100% |  | 2013-08-01 | 2013-08-01 | 20d |  |  |  | FNAD_CRYO_EN [85%] | 136h | 136h | 6,979.52 | 6,979.52 | 6,979.52 | +Cryo Basic Engineering BOE | Beams 4395 | Cryo1.03 | A1301.03 - Cryo Basic Engineering | 2894 |  | A1301.03 |  |  |
| 41 | Cryo1.03.02 | Basic Eng Drafting |  | 250d | 2013-06-17 A | 2014-06-13 A | 40SS, 22 | 100% |  | 2013-06-17 | 2014-06-13 | 250d |  |  | start no earlier than 2012-10-01 | FNAD_MECH_DRAFTER [28%] | 560h | 560h | 14,937.89 | 12,000.8 | 14,937.89 | +Cryo Basic Engineering BOE | Beams 4395 | Cryo1.03 | A1301.03 - Cryo Basic Engineering | 2497 | Need new start/predecessor | A1301.03 |  |  |
| 42 | Cryo1.03.03 | Basic engineering complete | milestone | 0d | 2014-09-30 A | 2014-09-30 A | 41, 43 | 100% |  | 2014-09-30 | 2014-09-30 | 0d |  |  |  |  |  |  |  |  |  |  |  |  |  |  | Successor? |  |  |  |
| 43 | Cryo1.03.04 | Basic Engineering OS |  | 251d | 2013-10-01 A | 2014-09-30 A | 5 | 100% |  | 2013-10-01 | 2014-09-30 | 251d |  |  |  | FNAD_CRYO_EN [74.7%] | 1500h | 1500h | 64,410 | 76,980 | 64,410 | +Cryo Basic Engineering BOE | Beams 4395 | Cryo1.03 | A1301.03 - Cryo Basic Engineering | 2832 |  | A1301.03 |  |  |
| 44 | Cryo1.03.05 | **Cryo Engineering** |  | 1d | 2015-03-02 A | 2015-03-02 A |  | 100% |  | 2014-10-01 | 2015-03-31 | 0d |  |  |  |  |  |  |  |  |  |  |  |  |  |  |  |  |  |  |
| 45 | Cryo1.03.05.01 | Cryo Mechanical Engineering ** Deleted ** |  | 1d | 2015-03-02 A | 2015-03-02 A |  | 100% |  | 2014-10-01 | 2015-03-31 | 1d |  |  | start no earlier than 2015-03-02 |  |  |  |  |  |  |  |  | Cryo1.03 | A1301.03 - Cryo Basic Engineering | 989 |  | A1301.03 |  | CR013 |
| 46 | Cryo1.03.05.02 | Cryo Controls Engineering ** Deleted ** |  | 1d | 2015-03-02 A | 2015-03-02 A |  | 100% |  | 2014-10-01 | 2015-03-31 | 1d |  |  | start no earlier than 2015-03-02 |  |  |  |  |  |  |  |  | Cryo1.03 | A1301.03 - Cryo Basic Engineering | 988 |  | A1301.03 |  | CR013 |
| 47 | Cryo1.03.05.03 | Cryo Electrical Engineering ** Deleted ** |  | 1d | 2015-03-02 A | 2015-03-02 A |  | 100% |  | 2014-10-01 | 2015-03-31 | 1d |  |  | start no earlier than 2015-03-02 |  |  |  |  |  |  |  |  | Cryo1.03 | A1301.03 - Cryo Basic Engineering | 990 |  | A1301.03 |  | CR013 |
| 48 | Cryo1.04 | **Cryogenic plant sub systems** |  | 677d | 2013-06-17 A | 2016-03-01 A |  | 100% |  | 2013-08-01 | 2015-06-24 | 656d |  |  |  |  | 13920h | 13920h | 2,288,075.07 | 2,306,740.35 | 2,288,075.11 |  |  | Cryo1.04 |  |  |  |  |  |  |
| 49 | Cryo1.04.01 | **Cryo LN2 system** |  | 251d | 2013-08-30 A | 2014-08-29 A |  | 100% |  | 2013-08-30 | 2014-09-02 | 252d |  |  |  |  | 2456h | 2456h | 209,825.26 | 238,772.26 | 209,825.28 | +Cryo LN2 System BOE | Beams 4395 | Cryo1.04.01 |  |  |  |  |  |  |
| 50 | Cryo1.04.01.01 | Basic Engineering - LN2 System |  | 61d | 2013-10-01 A | 2013-12-30 A | 5 | 100% |  | 2013-10-01 | 2014-01-06 | 64d |  |  | start no earlier than 2013-05-06 | FNAD_MECH_DRAFTER [4.5%] | 20h | 20h | 577.59 | 428.6 | 577.6 | +Cryo LN2 System BOE | Beams 4395 | Cryo1.04.01 | A1301.04.01 - Cryo LN2 system | 2421 |  | A1301.04.01 |  |  |
| 51 | Cryo1.04.01.02 | LN2 System Preparation |  | 82d | 2013-08-30 A | 2013-12-30 A | 52FF | 100% |  | 2013-08-30 | 2014-01-06 | 85d |  |  |  | FNAD_CRYO_EN [11.4%]; FNAD_CRYO_TECH [13.5%] | 148h | 148h | 5,493.96 | 5,809.76 | 5,493.96 | +Cryo LN2 System BOE | Beams 4395 | Cryo1.04.01 | A1301.04.01 - Cryo LN2 system | 2160 |  | A1301.04.01 |  |  |
| 52 | Cryo1.04.01.02 | Basic Engineering Complete - LN2 System | milestone | 0d | 2013-12-30 A | 2013-12-30 A | 50 | 100% |  | 2014-01-06 | 2014-01-06 | 0d |  |  |  |  |  |  |  |  |  |  |  |  |  |  |  |  |  |  |
| 53 | Cryo1.04.01.03 | LN2 System Procurement |  | 43d | 2013-10-01 A | 2013-12-02 A | 5 | 100% |  | 2013-10-01 | 2013-12-02 | 43d |  |  |  | FNAD_CRYO_TECH [7%]; FN_MS_STND_FY13 | 24h | 24h | 10,741.35 | 10,696 | 10,741.36 | +Cryo LN2 System BOE | Beams 4395 | Cryo1.04.01 | A1301.04.01 - Cryo LN2 system | 2838 |  | A1301.04.01 |  |  |
| 54 | Cryo1.04.01.04 | Fabrication - LN2 System |  | 61d | 2013-10-01 A | 2013-12-30 A | 50FF, 51FF | 100% |  | 2013-10-01 | 2014-01-06 | 64d |  |  |  | FNAD_CRYO_TECH [213.9%]; FN_MS_STND_FY13 | 960h | 960h | 49,654.4 | 47,840 | 49,654.4 | +Cryo LN2 System BOE | Beams 4395 | Cryo1.04.01 | A1301.04.01 - Cryo LN2 system | 2620 |  | A1301.04.01 |  |  |
| 55 | Cryo1.04.01.05 | Warm Weather Available for CHL Dewar Work | milestone | 0d | 2014-05-08 A | 2014-05-08 A |  | 100% |  | 2014-05-08 | 2014-05-08 | 0d |  |  | start no earlier than 2014-05-08 |  |  |  |  |  |  |  |  |  |  |  |  |  |  |  |
| 56 | Cryo1.04.01.06 | Indoor Installation - LN2 System |  | 27d | 2014-01-30 A | 2014-03-07 A | 54, 13FS+15d, 53 | 100% |  | 2014-01-30 | 2014-02-28 | 22d |  |  |  | FNAD_CRYO_TECH [231.5%]; FN_MS_STND_FY13 | 500h | 500h | 35,445 | 33,591.6 | 35,445 | +Cryo LN2 System BOE | Beams 4395 | Cryo1.04.01 | A1301.04.01 - Cryo LN2 system | 2839 |  | A1301.04.01 |  |  |
| 57 | Cryo1.04.01.07 | Preparing of LN2 dewar at CHL |  | 15d | 2014-05-08 A | 2014-05-29 A | 55 | 100% |  | 2014-05-08 | 2014-05-29 | 15d |  |  |  | FNAD_CRYO_TECH [16.7%] | 20h | 20h | 617.8 | 617.8 | 617.8 |  |  | Cryo1.04.01 | A1301.04.01 - Cryo LN2 system | 2902 |  | A1301.04.01 |  | CR002 |
| 58 | Cryo1.04.01.08 | Rigging of LN2 dewar from CHL to MC-1 |  | 1d | 2014-05-30 A | 2014-05-30 A | 57 | 100% |  | 2014-05-30 | 2014-06-03 | 3d |  |  |  | FNAD_CRYO_TECH [375%] | 30h | 30h | 926.7 | 926.7 | 926.7 |  |  | Cryo1.04.01 | A1301.04.01 - Cryo LN2 system | 2904 |  | A1301.04.01 |  | CR002 |
| 59 | Cryo1.04.01.09 | Outdoor Installation - LN2 System |  | 25d | 2014-06-03 A | 2014-07-08 A | 88FS+90d, 58 | 100% |  | 2014-06-04 | 2014-07-09 | 25d |  |  |  | FNAD_CRYO_TECH [125%]; FN_MS_STND_FY13 | 250h | 250h | 88,775.5 | 117,722.5 | 88,775.5 | +Cryo LN2 System BOE | Beams 4395 | Cryo1.04.01 | A1301.04.01 - Cryo LN2 system | 2499 | Need to detail the procurement. | A1301.04.01 |  | CR002, CR005 |
| 60 | Cryo1.04.01.10 | LN2 ORC |  | 38d | 2014-07-09 A | 2014-08-29 A | 59 | 100% |  | 2014-07-09 | 2014-07-09 | 0d |  |  |  |  |  |  |  |  |  |  |  |  |  |  |  |  |  |  |
| 61 | Cryo1.04.01.11 | LN2 Checkout |  | 20d | 2014-08-04 A | 2014-08-29 A | 59, 56, 57FS+45d | 100% |  | 2014-08-04 | 2014-09-02 | 21d |  |  |  | FNAD_CRYO_TECH [210%]; FNAD_CRYO_EN [105%] | 504h | 504h | 17,592.96 | 17,592.96 | 17,592.96 | +Cryo LN2 System BOE | Beams 4395 | Cryo1.04.01 | A1301.04.01 - Cryo LN2 system | 2841 |  | A1301.04.01 |  |  |
| 62 | Cryo1.04.01.12 | LN2 system is complete | milestone | 0d | 2014-08-29 A | 2014-08-29 A | 60, 61 | 100% |  | 2014-09-02 | 2014-09-02 | 0d |  |  |  |  |  |  |  |  |  |  |  |  |  |  |  |  |  |  |

Notes:
- 38: 20 trips @8 hours/trip = 160 hours TD Cryo Eng
- 59: 900 hours of rigging + misc M&S

| ID | WBS | Task | Type | Duration | Start | Finish | Predecessors | Complete | Baseline start | Baseline finish | Baseline duration | Constraint | Resources | Work | Actual work | Cost | Baseline cost | Actual cost | BOE File Name | BOE Number | Cobra WBS # | CTC + Name | Cobra WP ID | CTC | CR# |
| --- | --- | --- | --- | --- | --- | --- | --- | --- | --- | --- | --- | --- | --- | --- | --- | --- | --- | --- | --- | --- | --- | --- | --- | --- | --- |
| 63 | Cryo1.04.02 | **Cryo Gas management system** |  | 270d | 2013-06-17 A | 2014-07-14 A |  | 100% | 2013-08-01 | 2014-07-14 | 270d |  |  | 368h | 368h | 170,830.49 | 170,830.49 | 170,830.49 | +Cryo Gas Management System BOE | Beams 4395 | Cryo1.04.02 |  |  |  |  |
| 64 | Cryo1.04.02.01 | Prep Req & Process PO - GMS Valves & Components |  | 127d | 2013-06-27 A | 2013-12-30 A |  | 100% | 2013-08-01 | 2014-02-18 | 160d | start no earlier than 2013-06-27 | FNAD_CRYO_TECH [1.6%] | 8h | 8h | 240.78 | 232 | 240.78 | +Cryo Gas Management System BOE | Beams 4395 | Cryo1.04.02 | A1301.04.02 - Cryo Gas management system | 2585 | A1301.04.02 |  |
| 65 | Cryo1.04.02.02 | 1st Award - GMS Valves & Components |  | 0.12d | 2013-08-27 A | 2013-08-27 A | 64SS+42d | 100% | 2013-08-27 | 2013-08-27 | 0.12d |  |  |  |  |  |  |  | +Cryo Gas Management System BOE | Beams 4395 | Cryo1.04.02 | A1301.04.02 - Cryo Gas management system | 2586 | A1301.04.02 |  |
| 66 | Cryo1.04.02.03 | 1st Delivery - GMS Valves & Components |  | 42d | 2013-08-30 A | 2013-10-30 A | 65FF+45d | 100% | 2013-09-03 | 2013-10-30 | 42d |  | FN_MS_STND_FY13 |  |  | 20,964 | 20,964 | 20,964 | +Cryo Gas Management System BOE | Beams 4395 | Cryo1.04.02 | A1301.04.02 - Cryo Gas management system | 2587 | A1301.04.02 |  |
| 67 | Cryo1.04.02.04 | 2nd Award - GMS Tank Farm Valves & Components |  | 102d | 2013-10-01 A | 2014-02-28 A | 64FF+20d, 5 | 100% | 2013-10-01 | 2014-03-26 | 120d | finish no earlier than 2014-02-28 |  |  |  |  |  |  | +Cryo Gas Management System BOE | Beams 4395 | Cryo1.04.02 | A1301.04.02 - Cryo Gas management system | 2588 | A1301.04.02 |  |
| 68 | Cryo1.04.02.05 | 2nd Delivery - GMS Tank Farm Valves & Components |  | 75d | 2013-10-15 A | 2014-02-05 A | 67SS+10d | 100% | 2013-10-15 | 2014-05-21 | 150d |  | FN_MS_STND_FY13 |  |  | 65,000 | 65,000 | 65,000 | +Cryo Gas Management System BOE | Beams 4395 | Cryo1.04.02 | A1301.04.02 - Cryo Gas management system | 2589 | A1301.04.02 |  |
| 69 | Cryo1.04.02.06 | Interconnect Piping Award A0 Inventory Control Piping |  | 0.12d | 2013-08-30 A | 2013-08-30 A | 190FS+5d | 100% | 2013-08-30 | 2013-08-30 | 0.12d |  |  |  |  |  |  |  | +Cryo Interconnect Piping BOE | Beams 4395 | Cryo1.04.02 | A1301.04.02 - Cryo Gas management system | 2895 | A1301.04.02 |  |
| 70 | Cryo1.04.02.07 | Interconnect Piping Deliver & Install A0 Inventory Control Piping |  | 60d | 2013-08-30 A | 2013-11-25 A | 69 | 100% | 2013-09-03 | 2013-11-25 | 60d |  | FN_MS_STND_FY13 |  |  | 70,000 | 70,000 | 70,000 | +Cryo Interconnect Piping BOE | Beams 4395 | Cryo1.04.02 | A1301.04.02 - Cryo Gas management system | 2896 | A1301.04.02 |  |
| 71 | Cryo1.04.02.08 | Task Management - GMS |  | 62d | 2013-09-17 A | 2013-12-13 A | 73SS-10d | 100% | 2013-09-17 | 2013-12-13 | 62d |  | FNAD_CRYO_TECH [16.1%]; FNAD_CRYO_EN [10.5%] | 132h | 132h | 4,749.59 | 4,988.64 | 4,749.59 | +Cryo Gas Management System BOE | Beams 4395 | Cryo1.04.02 | A1301.04.02 - Cryo Gas management system | 2624 | A1301.04.02 |  |
| 72 | Cryo1.04.02.09 | Fabrication - GMS |  | 15d | 2013-06-17 A | 2013-07-08 A | 4FS+10d | 100% | 2013-08-01 | 2013-08-01 | 15d |  | FNAD_CRYO_TECH [66.7%]; FNAD_CRYO_EN [33.3%] | 120h | 120h | 4,370.4 | 4,372.8 | 4,370.4 | +Cryo Gas Management System BOE | Beams 4395 | Cryo1.04.02 | A1301.04.02 - Cryo Gas management system | 2604 | A1301.04.02 |  |
| 73 | Cryo1.04.02.10 | Installation - GMS |  | 57d | 2013-10-01 A | 2013-12-20 A | 66FF, 72FF, 5 | 100% | 2013-10-01 | 2013-12-20 | 57d |  | FNAD_CRYO_TECH [9.6%]; FN_MS_STND_FY13 [178400%] | 44h | 44h | 3,143.16 | 3,060 | 3,143.16 | +Cryo Gas Management System BOE | Beams 4395 | Cryo1.04.02 | A1301.04.02 - Cryo Gas management system | 2584 | A1301.04.02 |  |
| 74 | Cryo1.04.02.11 | Installed - GMS | milestone | 0d | 2013-12-20 A | 2013-12-20 A | 73 | 100% | 2013-12-20 | 2013-12-20 | 0d |  |  |  |  |  |  |  |  |  |  |  |  |  |  |
| 75 | Cryo1.04.02.12 | Checkout - GMS |  | 4d | 2014-07-09 A | 2014-07-14 A | 73FS+135d, 68FF | 100% | 2014-07-09 | 2014-07-14 | 4d |  | FNAD_CRYO_TECH; FNAD_CRYO_EN | 64h | 64h | 2,362.56 | 2,362.56 | 2,362.56 |  |  | Cryo1.04.02 | A1301.04.02 - Cryo Gas management system | 2842 | A1301.04.02 |  |
| 76 | Cryo1.04.02.13 | GMS is complete | milestone | 0d | 2013-12-30 A | 2013-12-30 A | 75, 71, 74 | 100% | 2014-01-02 | 2014-01-02 | 0d |  |  |  |  |  |  |  |  |  |  |  |  |  |  |
| 77 | Cryo1.04.03 | **Cryo ODH system** |  | 79d | 2014-05-05 A | 2014-08-25 A |  | 100% | 2014-05-05 | 2014-08-26 | 80d |  |  | 58h | 58h | 37,056.72 | 37,056.72 | 37,056.72 | +Cryo ODH System BOE | Beams 4395 | Cryo1.04.03 |  |  |  |  |
| 78 | Cryo1.04.03.01 | Procure ODH Equipment |  | 19d | 2014-05-05 A | 2014-05-30 A | 5FS+147d | 100% | 2014-05-05 | 2014-06-02 | 20d |  | FNAD_CRYO_TECH [10.5%]; FN_MS_STND_FY13 | 16h | 16h | 30,494.24 | 30,494.24 | 30,494.24 | +Cryo ODH System BOE | Beams 4395 | Cryo1.04.03 | A1301.04.03 - Cryo ODH system | 2582 | A1301.04.03 |  |
| 79 | Cryo1.04.03.02 | Install ODH Equipment |  | 60d | 2014-06-02 A | 2014-08-25 A | 78FF+60d | 100% | 2014-06-03 | 2014-08-26 | 60d |  | FNAD_CRYO_TECH [4.2%]; FNAD_CRYO_EN [4.6%]; FN_MS_STND_FY13 [500000%] | 42h | 42h | 6,562.48 | 6,562.48 | 6,562.48 | +Cryo ODH System BOE | Beams 4395 | Cryo1.04.03 | A1301.04.03 - Cryo ODH system | 2583 | A1301.04.03 | CR002 |
| 80 | Cryo1.04.04 | **Cryo Refrigerator System** |  | 448d | 2013-06-17 A | 2015-03-31 A |  | 100% | 2013-08-01 | 2015-04-07 | 656d | start no earlier than 2012-11-05 |  | 6296h | 6296h | 831,891.99 | 968,651.54 | 831,892.01 | +Cryo Refrigeration System BOE | Beams 4395 | Cryo1.04.04 |  |  |  |  |
| 81 | Cryo1.04.04.01 | **Refrigerator System U-tubes** |  | 20d | 2014-08-11 A | 2014-09-08 A |  | 100% | 2014-08-11 | 2014-09-08 | 20d |  |  | 276h | 276h | 38,177.84 | 38,177.84 | 38,177.84 | +Cryo Refrigeration System BOE | Beams 4395 |  |  |  |  |  |
| 82 | Cryo1.04.04.01.01 | Design & Fabricate U-tubes |  | 20d | 2014-08-11 A | 2014-09-08 A | 5FS+215d | 100% | 2014-08-11 | 2014-09-08 | 20d |  | FNAD_MECH_DRAFTER [50%]; FNAD_CRYO_TECH [85%]; FNAD_CRYO_EN [37.5%]; FN_MS_STND_FY13 | 276h | 276h | 38,177.84 | 38,177.84 | 38,177.84 | +Cryo Refrigeration System BOE | Beams 4395 | Cryo1.04.04 | A1301.04.04 - Cryo Refrigerator System | 2725 | A1301.04.04 | CR002 |
| 83 | Cryo1.04.04.01.02 | U-tubes Complete | milestone | 0d | 2014-09-08 A | 2014-09-08 A | 82 | 100% | 2014-09-08 | 2014-09-08 | 0d |  |  |  |  |  |  |  |  |  |  |  |  |  |  |
| 84 | Cryo1.04.04.02 | **Refrig Syst Heat exchangers** |  | 222d | 2013-09-17 A | 2014-08-05 A |  | 100% | 2013-09-17 | 2014-08-06 | 223d |  |  | 1006h | 1006h | 59,063.27 | 56,388.27 | 59,063.27 | +Cryo Refrigeration System BOE | Beams 4395 | Cryo1.04.04 |  |  |  |  |
| 85 | Cryo1.04.04.02.01 | **Prep Heat Exchangers for Installation** |  | 222d | 2013-09-17 A | 2014-08-05 A |  | 100% | 2013-09-17 | 2014-08-06 | 223d |  |  | 1006h | 1006h | 59,063.27 | 56,388.27 | 59,063.27 | +Cryo Refrigeration System BOE | Beams 4395 |  |  |  |  |  |
| 86 | Cryo1.04.04.02.01.01 | Prep Heat Exchangers & Test |  | 67d | 2013-09-17 A | 2013-12-20 A | 22FS+64d | 100% | 2013-09-17 | 2013-12-20 | 67d |  | FNAD_CRYO_TECH [110.1%] | 590h | 590h | 18,056.03 | 17,110 | 18,056.03 | +Cryo Refrigeration System BOE | Beams 4395 | Cryo1.04.04 | A1301.04.04 - Cryo Refrigerator System | 1269 | A1301.04.04 |  |
| 87 | Cryo1.04.04.02.01.02 | Heat Exchanger Procurement |  | 61d | 2013-10-01 A | 2013-12-30 A | 5 | 100% | 2013-10-01 | 2014-01-09 | 67d |  | FNAD_CRYO_TECH [3.8%]; FN_MS_STND_FY13 | 16h | 16h | 10,494.24 | 10,464 | 10,494.24 |  |  | Cryo1.04.04 | A1301.04.04 - Cryo Refrigerator System | 2843 | A1301.04.04 |  |
| 88 | Cryo1.04.04.02.01.03 | Heat Exchanger Rigging |  | 10d | 2014-01-10 A | 2014-01-24 A | 13FS+2d, 86, 87 | 100% | 2014-01-10 | 2014-01-24 | 10d |  | FNAD_CRYO_EN [50%]; FN_MS_STND_FY13 | 40h | 40h | 16,717.6 | 17,052.8 | 16,717.6 |  |  | Cryo1.04.04 | A1301.04.04 - Cryo Refrigerator System | 2844 | A1301.04.04 |  |
| 89 | Cryo1.04.04.02.01.04 | Heat Exchanger Suction Parallel Plate Installation |  | 12d | 2014-02-13 A | 2014-02-28 A | 88FS+13d | 100% | 2014-02-13 | 2014-03-05 | 15d |  | FNAD_CRYO_TECH [125%] | 120h | 120h | 3,706.8 | 3,706.8 | 3,706.8 |  |  | Cryo1.04.04 | A1301.04.04 - Cryo Refrigerator System | 2906 | A1301.04.04 | CR002 |
| 90 | Cryo1.04.04.02.01.05 | Heat Exchangers Recondition Valves |  | 10d | 2014-02-17 A | 2014-02-28 A | 89FF | 100% | 2014-03-06 | 2014-03-19 | 10d |  | FNAD_CRYO_TECH | 80h | 80h | 2,471.2 | 2,471.2 | 2,471.2 |  |  | Cryo1.04.04 | A1301.04.04 - Cryo Refrigerator System | 2905 | A1301.04.04 | CR002 |
| 91 | Cryo1.04.04.02.01.06 | Paint Heat Exchangers |  | 11d | 2014-05-05 A | 2014-05-19 A | 5FS+147d | 100% | 2014-04-01 | 2014-04-15 | 0d |  | FN_MS_EXMP_FY13 [267500%]; FN_MS_STND_FY13 [267500%] |  |  | 2,675 |  | 2,675 |  |  | Cryo1.04.04 | A1301.04.04 - Cryo Refrigerator System | 2917 | A1301.04.04 | CR003 |
| 92 | Cryo1.04.04.02.01.07 | Heat Exchanger N2 Vent and Common Header Installation |  | 20d | 2014-07-09 A | 2014-08-05 A | 59 | 100% | 2014-07-10 | 2014-08-06 | 20d |  | FNAD_CRYO_TECH | 160h | 160h | 4,942.4 | 4,942.4 | 4,942.4 |  |  | Cryo1.04.04 | A1301.04.04 - Cryo Refrigerator System | 2907 | A1301.04.04 | CR002 |
| 93 | Cryo1.04.04.02.02 | Refrig Syst Heat Exchangers Complete | milestone | 0d | 2014-08-05 A | 2014-08-05 A | 88, 92, 91 | 100% | 2014-08-06 | 2014-08-06 | 0d |  |  |  |  |  |  |  |  |  |  |  |  |  |  |

Notes:
- 76: Text20: Successor?
- 77: Text20: What is the scope of this task? Kind of hard to determine from the name. Successor?
- 82: Text20: What is the scope of this task? Kind of hard to determine from the name.
- 83: Text20: Successor?
- 93: Text20: Successor?

| ID | WBS | Task | Type | Duration | Start | Finish | Predecessors | Complete | Baseline start | Baseline finish | Baseline duration | Constraint | Resources | Work | Actual work | Cost | Baseline cost | Actual cost | BOE File Name | BOE Number | CTC + Name | Cobra WP ID | Cobra WBS # | CTC | CR# | Text20 |
| --- | --- | --- | --- | --- | --- | --- | --- | --- | --- | --- | --- | --- | --- | --- | --- | --- | --- | --- | --- | --- | --- | --- | --- | --- | --- | --- |
| 94 | Cryo1.04.04.03 | **Refrig Syst Expanders** |  | 48d | 2014-07-31 A | 2014-10-07 A |  | 100% | 2014-07-03 | 2014-09-17 | 53d |  |  | 140h | 140h | 10,047.6 | 10,047.6 | 10,047.6 | +Cryo Refrigeration System BOE | Beams 4395 |  |  |  |  |  |  |
| 95 | Cryo1.04.04.03.01 | Refrig Syst Expanders Installation |  | 10d | 2014-07-31 A | 2014-08-13 A | 13FS+100d, 127 | 100% | 2014-07-03 | 2014-07-17 | 10d |  | FNAD_CRYO_TECH; FNAD_CRYO_EN [45%]; FN_MS_STND_FY13 [500000%] | 116h | 116h | 9,017.04 | 9,017.04 | 9,017.04 | +Cryo Refrigeration System BOE | Beams 4395 | A1301.04.04 - Cryo Refrigerator System | 1375 | Cryo1.04.04 | A1301.04.04 | CR002 |  |
| 96 | Cryo1.04.04.03.02 | Refrig Syst Expanders Testing & Validation |  | 5d | 2014-10-01 A | 2014-10-07 A | 95FS+20d, 23FS+10d, 139FS+28d | 100% | 2014-09-11 | 2014-09-17 | 5d |  | FNAD_CRYO_EN [60%] | 24h | 24h | 1,030.56 | 1,030.56 | 1,030.56 |  |  | A1301.04.04 - Cryo Refrigerator System | 2873 | Cryo1.04.04 | A1301.04.04 |  |  |
| 97 | Cryo1.04.04.03.03 | Refrig Syst Expanders Complete | milestone | 0d | 2014-10-07 A | 2014-10-07 A | 96 | 100% | 2014-09-17 | 2014-09-17 | 0d |  |  |  |  |  |  |  |  |  |  |  |  |  |  |  |
| 98 | Cryo1.04.04.04 | **Refrig Syst Controls** |  | 325d | 2013-06-17 A | 2014-09-30 A |  | 100% | 2013-08-01 | 2014-10-24 | 343d |  |  | 680h | 680h | 171,299.2 | 171,299.15 | 171,299.2 | +Cryo Refrigeration System BOE | Beams 4395 |  |  |  |  |  |  |
| 99 | Cryo1.04.04.04.01 | **Refrig Syst DCS** |  | 325d | 2013-06-17 A | 2014-09-30 A |  | 100% | 2013-08-01 | 2014-10-24 | 343d |  |  | 680h | 680h | 171,299.2 | 171,299.15 | 171,299.2 | +Cryo Refrigeration System BOE |  |  |  |  |  |  |  |
| 100 | Cryo1.04.04.04.01.01 | Refrig Syst DCS Detailed Engineering |  | 231d | 2013-10-01 A | 2014-09-02 A | 5 | 100% | 2013-10-01 | 2014-09-02 | 231d |  | FNAD_CRYO_EN [32.5%] | 600h | 600h | 25,764 | 30,792 | 25,764 |  |  | A1301.04.04 - Cryo Refrigerator System | 2845 | Cryo1.04.04 | A1301.04.04 |  |  |
| 101 | Cryo1.04.04.04.01.02 | Refrig Syst - First Award for DCS (FY13) |  | 0.12d | 2013-06-17 A | 2013-06-17 A | 22 | 100% | 2013-08-01 | 2013-08-01 | 0.12d |  |  |  |  |  |  |  | +Cryo Refrigeration System BOE | Beams 4395 | A1301.04.04 - Cryo Refrigerator System | 2889 | Cryo1.04.04 | A1301.04.04 |  | Successor? What is this award for? |
| 102 | Cryo1.04.04.04.01.03 | Refrig Syst - 1st DCS Delivery Received |  | 43d | 2013-07-01 A | 2013-08-30 A | 101FS+10d | 100% | 2013-08-01 | 2013-08-30 | 43d |  | FN_MS_STND_FY13 |  |  | 112,100 | 112,100 | 112,100 | +Cryo Refrigeration System BOE | Beams 4395 | A1301.04.04 - Cryo Refrigerator System | 2890 | Cryo1.04.04 | A1301.04.04 |  |  |
| 103 | Cryo1.04.04.04.01.04 | Refrig Syst - Second Award for DCS (FY15) |  | 100d | 2014-01-02 A | 2014-05-22 A | 5 | 100% | 2014-01-02 | 2014-05-22 | 100d | start no earlier than 2014-01-02 |  |  |  |  |  |  | +Cryo Refrigeration System BOE | Beams 4395 | A1301.04.04 - Cryo Refrigerator System | 2891 | Cryo1.04.04 | A1301.04.04 |  | Successor? What is this award for? |
| 104 | Cryo1.04.04.04.01.05 | Refrig Syst - 2nd DCS Delivery Received |  | 140d | 2014-03-07 A | 2014-09-23 A | 103FF+85d | 100% | 2014-06-02 | 2014-09-23 | 80d |  | FN_MS_STND_FY13 |  |  | 30,000 | 30,000 | 30,000 | +Cryo Refrigeration System BOE | Beams 4395 | A1301.04.04 - Cryo Refrigerator System | 2892 | Cryo1.04.04 | A1301.04.04 | CR002 |  |
| 105 | Cryo1.04.04.04.01.06 | Refrig Syst Testing & Validation |  | 5d | 2014-09-24 A | 2014-09-30 A | 100FS+13d, 104, 102 | 100% | 2014-09-24 | 2014-10-24 | 23d |  | FNAD_CRYO_EN [200%] | 80h | 80h | 3,435.2 | 3,435.2 | 3,435.2 |  |  | A1301.04.04 - Cryo Refrigerator System | 2846 | Cryo1.04.04 | A1301.04.04 |  |  |
| 106 | Cryo1.04.04.04.02 | Refrig Syst Controls Complete | milestone | 0d | 2014-09-30 A | 2014-09-30 A | 105 | 100% | 2014-10-24 | 2014-10-24 | 0d |  |  |  |  |  |  |  |  |  |  |  |  |  |  |  |
| 107 | Cryo1.04.04.05 | **Refrig Syst Electrical Infrastructure** |  | 338d | 2013-08-13 A | 2014-12-16 A |  | 100% | 2013-08-13 | 2014-12-26 | 344d |  |  | 230h | 230h | 188,671.93 | 188,671.93 | 188,671.94 | +Cryo Refrigeration System BOE | Beams 4395 |  |  | Cryo1.04.04 |  |  |  |
| 108 | Cryo1.04.04.05.01 | Refrig Syst Electrical - Prep Req & Process PO for Electrical T&M |  | 94d | 2013-08-13 A | 2013-12-27 A | 22FS+40d | 100% | 2013-08-13 | 2013-12-27 | 94d |  | FNAD_CRYO_EN [5.3%] | 40h | 40h | 1,838.83 | 2,052.8 | 1,838.84 | +Cryo Refrigeration System BOE | Beams 4395 | A1301.04.04 - Cryo Refrigerator System | 2664 | Cryo1.04.04 | A1301.04.04 |  |  |
| 109 | Cryo1.04.04.05.02 | Refrig Syst Electrical - 1st Award POs for Electrical Work |  | 41d | 2013-10-02 A | 2013-11-27 A | 108SS+35d | 100% | 2013-10-02 | 2013-12-30 | 41d |  |  |  |  |  |  |  | +Cryo Refrigeration System BOE | Beams 4395 | A1301.04.04 - Cryo Refrigerator System | 2665 | Cryo1.04.04 | A1301.04.04 |  |  |
| 110 | Cryo1.04.04.05.03 | Refrig Syst Electrical - 1st Receive Matl for Electrical Work |  | 110d | 2013-10-02 A | 2014-03-13 A | 109SS | 100% | 2013-10-02 | 2014-03-13 | 110d |  | FN_MS_STND_FY13 |  |  | 120,000 | 120,000 | 120,000 |  | Beams 4395 | A1301.04.04 - Cryo Refrigerator System | 2878 | Cryo1.04.04 | A1301.04.04 |  |  |
| 111 | Cryo1.04.04.05.04 | Refrig Syst Electrical - 2nd Award POs for Electrical Work |  | 124d | 2014-05-08 A | 2014-10-31 A | 108FS+90d | 100% | 2014-03-27 | 2014-10-20 | 145d |  |  |  |  |  |  |  |  | Beams 4395 | A1301.04.04 - Cryo Refrigerator System | 2877 | Cryo1.04.04 | A1301.04.04 |  |  |
| 112 | Cryo1.04.04.05.05 | Refrig Syst Electrical - 2nd Receive Matl for Electrical Work |  | 109d | 2014-07-14 A | 2014-12-16 A | 111FF+30d | 100% | 2014-05-08 | 2014-12-26 | 160d |  | FN_MS_STND_FY13 |  |  | 60,000 | 60,000 | 60,000 |  | Beams 4395 | A1301.04.04 - Cryo Refrigerator System | 2879 | Cryo1.04.04 | A1301.04.04 |  |  |
| 113 | Cryo1.04.04.05.06 | Refrig Syst Electrical - Installation (T&M Oversight) Phase 1 |  | 40d | 2014-01-16 A | 2014-03-13 A | 110FF | 100% | 2014-01-16 | 2014-03-13 | 40d |  | FNAD_CRYO_EN [12.5%] | 40h | 40h | 1,717.6 | 2,052.8 | 1,717.6 | +Cryo Refrigeration System BOE | Beams 4395 | A1301.04.04 - Cryo Refrigerator System | 2666 | Cryo1.04.04 | A1301.04.04 |  |  |
| 114 | Cryo1.04.04.05.07 | Refrig Syst Electrical T&M Complete | milestone | 0d | 2014-08-13 A | 2014-08-13 A | 115 | 100% | 2014-08-07 | 2014-08-07 | 0d |  |  |  |  |  |  |  |  |  |  |  |  |  |  | Successor? |
| 115 | Cryo1.04.04.05.08 | Refrig Syst Electrical - Installation (T&M Oversight) Phase 2 |  | 15d | 2014-07-24 A | 2014-08-13 A | 95FF, 113FF | 100% | 2014-07-18 | 2014-08-07 | 15d |  | FNAD_CRYO_EN [33.3%]; FNAD_CRYO_TECH [91.7%] | 150h | 150h | 5,115.5 | 5,115.5 | 5,115.5 |  |  | A1301.04.04 - Cryo Refrigerator System | 2913 | Cryo1.04.04 | A1301.04.04 | CR002 |  |
| 116 | Cryo1.04.04.06 | **Refrig Syst Painting** |  | 60d | 2014-03-07 A | 2014-05-30 A |  | 100% | 2014-04-03 | 2014-10-30 | 148d |  |  | 68h | 68h | 31,900.52 | 31,900.52 | 31,900.52 | +Cryo Refrigeration System BOE | Beams 4395 |  |  |  |  |  |  |
| 117 | Cryo1.04.04.06.01 | Refrig Syst Painting - Prep Req & Process PO |  | 40d | 2014-04-03 A | 2014-05-29 A | 5FS+125d | 100% | 2014-04-03 | 2014-07-14 | 71d |  | FNAD_CRYO_TECH [1.8%] | 4h | 4h | 123.56 | 123.56 | 123.56 | +Cryo Refrigeration System BOE | Beams 4395 | A1301.04.04 - Cryo Refrigerator System | 2733 | Cryo1.04.04 | A1301.04.04 |  |  |
| 118 | Cryo1.04.04.06.02 | Refrig Syst Painting - Award PO |  | 1d | 2014-05-30 A | 2014-05-30 A | 117 | 100% | 2014-07-15 | 2014-07-30 | 12d |  |  |  |  |  |  |  | +Cryo Refrigeration System BOE | Beams 4395 | A1301.04.04 - Cryo Refrigerator System | 2734 | Cryo1.04.04 | A1301.04.04 |  |  |
| 119 | Cryo1.04.04.06.03 | Refrig Syst Painting T&M |  | 60d | 2014-03-07 A | 2014-05-30 A | 118FF | 100% | 2014-08-07 | 2014-10-30 | 60d |  | FNAD_CRYO_TECH [13.3%]; FN_MS_STND_FY13 | 64h | 64h | 31,776.96 | 31,776.96 | 31,776.96 | +Cryo Refrigeration System BOE | Beams 4395 | A1301.04.04 - Cryo Refrigerator System | 2735 | Cryo1.04.04 | A1301.04.04 |  | Successor? |
| 120 | Cryo1.04.04.06.04 | Refrig Syst Painting Complete | milestone | 0d | 2014-05-30 A | 2014-05-30 A | 119 | 100% | 2014-10-30 | 2014-10-30 | 0d |  |  |  |  |  |  |  |  |  |  |  |  |  |  |  |

| ID | WBS | Task | Duration | Start | Finish | Predecessors | Complete | Baseline start | Baseline finish | Baseline duration | Resources | Work | Actual work | Cost | Baseline cost | Actual cost | BOE File Name | BOE Number | CTC + Name | Cobra WP ID | Cobra WBS # | CTC | CR# |
| --- | --- | --- | --- | --- | --- | --- | --- | --- | --- | --- | --- | --- | --- | --- | --- | --- | --- | --- | --- | --- | --- | --- | --- |
| 121 | Cryo1.04.04.07 | **Refrig Syst Distribution System** | 374d | 2013-10-01 A | 2015-03-31 A |  | 100% | 2013-10-01 | 2015-04-07 | 582d |  | 3896h | 3896h | 289,308.63 | 472,166.23 | 289,308.64 | +Cryo Refrigeration System BOE | Beams 4395 |  |  |  |  |  |
| 122 | Cryo1.04.04.07.01 | **Refrigeration Syst Valve Box** | 213d | 2013-10-01 A | 2014-08-06 A |  | 100% | 2013-10-01 | 2014-08-01 | 210d |  | 760h | 760h | 49,826 | 49,826 | 49,826 |  |  |  |  |  |  |  |
| 123 | Cryo1.04.04.07.01.01 | Refrigeration Syst Valve Box Procurement | 24d | 2013-10-01 A | 2013-11-01 A | 5 | 100% | 2013-10-01 | 2013-11-01 | 24d | FNAD_CRYO_TECH [4.2%]; FN_MS_STND_FY13 | 8h | 8h | 15,247.12 | 15,232 | 15,247.12 |  |  | A1301.04.04 - Cryo Refrigerator System | 2848 | Cryo1.04.04 | A1301.04.04 |  |
| 124 | Cryo1.04.04.07.01.02 | Refrigeration Syst g-2 Valve Box Fabrication | 20d | 2014-03-12 A | 2014-04-08 A | 123FS+85d | 100% | 2014-03-12 | 2014-04-08 | 20d | FNAD_CRYO_TECH; FNAD_CRYO_EN [20%] | 192h | 192h | 6,316.48 | 6,316.48 | 6,316.48 |  |  | A1301.04.04 - Cryo Refrigerator System | 2849 | Cryo1.04.04 | A1301.04.04 | CR002 |
| 125 | Cryo1.04.04.07.01.03 | Refrigeration Syst Mu2e Valve Box Fabrication | 20d | 2014-04-09 A | 2014-05-06 A | 124 | 100% | 2014-04-09 | 2014-05-06 | 20d | FNAD_CRYO_TECH; FNAD_CRYO_EN [20%] | 192h | 192h | 6,316.48 | 6,316.48 | 6,316.48 |  |  | A1301.04.04 - Cryo Refrigerator System | 2908 | Cryo1.04.04 | A1301.04.04 | CR002 |
| 126 | Cryo1.04.04.07.01.04 | Refrigeration Syst g-2 Valve Box Installation | 27d | 2014-05-15 A | 2014-06-23 A | 124, 150FF+10d | 100% | 2014-05-21 | 2014-06-04 | 10d | FNAD_CRYO_TECH [74.1%]; FNAD_CRYO_EN [5.6%]; FN_MS_STND_FY13 [500000%] | 172h | 172h | 10,457.68 | 10,457.68 | 10,457.68 |  |  | A1301.04.04 - Cryo Refrigerator System | 2850 | Cryo1.04.04 | A1301.04.04 | CR002 |
| 127 | Cryo1.04.04.07.01.05 | Refrigeration Syst Mu2e Valve Box Installation | 10d | 2014-07-17 A | 2014-07-30 A | 125, 138 | 100% | 2014-06-19 | 2014-07-02 | 10d | FNAD_CRYO_TECH [200%]; FNAD_CRYO_EN [15%]; FN_MS_STND_FY13 [500000%] | 172h | 172h | 10,457.68 | 10,457.68 | 10,457.68 |  |  | A1301.04.04 - Cryo Refrigerator System | 2909 | Cryo1.04.04 | A1301.04.04 | CR002 |
| 128 | Cryo1.04.04.07.01.06 | Refrigeration Syst Valve Box Checkout | 21d | 2014-07-09 A | 2014-08-06 A | 126, 127FF+5d | 100% | 2014-07-03 | 2014-08-01 | 21d | FNAD_CRYO_EN [14.3%] | 24h | 24h | 1,030.56 | 1,030.56 | 1,030.56 |  |  | A1301.04.04 - Cryo Refrigerator System | 2851 | Cryo1.04.04 | A1301.04.04 |  |
| 129 | Cryo1.04.04.07.02 | **Refrigeration Syst AP-10 Bayonet Can** | 156d | 2014-01-03 A | 2014-08-13 A |  | 100% | 2014-01-03 | 2014-08-15 | 158d |  | 416h | 416h | 28,814.24 | 28,814.24 | 28,814.24 |  |  |  |  |  |  |  |
| 130 | Cryo1.04.04.07.02.01 | Refrigeration Syst AP-10 Bayonet Can Procurement | 34d | 2014-01-03 A | 2014-02-20 A | 5FS+62d | 100% | 2014-01-03 | 2014-02-20 | 34d | FNAD_CRYO_TECH [2.9%]; FN_MS_STND_FY13 [500000%] | 8h | 8h | 5,247.12 | 5,232 | 5,247.12 |  |  | A1301.04.04 - Cryo Refrigerator System | 2853 | Cryo1.04.04 | A1301.04.04 |  |
| 131 | Cryo1.04.04.07.02.02 | Refrigeration Syst AP-10 Bayonet Can Fabrication | 14d | 2014-02-21 A | 2014-03-12 A | 130 | 100% | 2014-02-21 | 2014-03-12 | 14d | FNAD_CRYO_EN [71.4%] | 80h | 80h | 3,435.2 | 3,435.2 | 3,435.2 |  |  | A1301.04.04 - Cryo Refrigerator System | 2854 | Cryo1.04.04 | A1301.04.04 |  |
| 132 | Cryo1.04.04.07.02.03 | Refrigeration Syst AP-10 Bayonet Can Installation | 10d | 2014-07-17 A | 2014-07-30 A | 131FS+50d, 127FF | 100% | 2014-07-03 | 2014-07-17 | 10d | FNAD_CRYO_TECH [200%]; FN_MS_STND_FY13 | 160h | 160h | 14,942.4 | 14,942.4 | 14,942.4 |  |  | A1301.04.04 - Cryo Refrigerator System | 2855 | Cryo1.04.04 | A1301.04.04 | CR002 |
| 133 | Cryo1.04.04.07.02.04 | Refrigeration Syst AP-10 Bayonet Can Checkout | 21d | 2014-07-16 A | 2014-08-13 A | 132FF+10d | 100% | 2014-07-18 | 2014-08-15 | 21d | FNAD_CRYO_TECH | 168h | 168h | 5,189.52 | 5,189.52 | 5,189.52 |  |  | A1301.04.04 - Cryo Refrigerator System | 2856 | Cryo1.04.04 | A1301.04.04 |  |
| 134 | Cryo1.04.04.07.03 | **Refrigeration Syst Transfer Lines** | 223d | 2013-10-01 A | 2014-08-20 A |  | 100% | 2013-10-01 | 2014-07-31 | 209d |  | 1152h | 1152h | 86,374.47 | 60,874.47 | 86,374.48 |  |  |  |  |  |  |  |
| 135 | Cryo1.04.04.07.03.01 | Refrigeration Syst Transfer Lines Procurement | 42d | 2013-10-01 A | 2013-11-27 A | 5 | 100% | 2013-10-01 | 2013-12-02 | 43d | FNAD_CRYO_TECH [2.4%]; FN_MS_STND_FY13 | 8h | 8h | 15,247.11 | 15,232 | 15,247.12 |  |  | A1301.04.04 - Cryo Refrigerator System | 2858 | Cryo1.04.04 | A1301.04.04 |  |
| 136 | Cryo1.04.04.07.03.02 | Refrigeration Syst Transfer Lines Fabrication | 60d | 2013-12-02 A | 2014-02-28 A | 135 | 100% | 2013-12-03 | 2014-03-03 | 60d | FNAD_CRYO_TECH [83.3%] | 400h | 400h | 12,356 | 11,600 | 12,356 |  |  | A1301.04.04 - Cryo Refrigerator System | 2859 | Cryo1.04.04 | A1301.04.04 |  |
| 137 | Cryo1.04.04.07.03.03 | Refrigeration Syst Transfer Lines Installation | 48d | 2014-04-24 A | 2014-07-01 A | 136, 149FS+18d | 100% | 2014-04-07 | 2014-05-09 | 25d | FNAD_CRYO_TECH [104.2%]; FN_MS_STND_FY13 | 400h | 400h | 47,856 | 22,356 | 47,856 |  |  | A1301.04.04 - Cryo Refrigerator System | 2860 | Cryo1.04.04 | A1301.04.04 | CR002 ,CR004 |
| 138 | Cryo1.04.04.07.03.04 | Refrigeration Syst g-2 Transfer Lines Checkout | 10d | 2014-07-02 A | 2014-07-16 A | 137, 126 | 100% | 2014-06-05 | 2014-06-18 | 10d | FNAD_CRYO_EN [15%]; FNAD_CRYO_TECH [200%] | 172h | 172h | 5,457.68 | 5,457.68 | 5,457.68 |  |  | A1301.04.04 - Cryo Refrigerator System | 2861 | Cryo1.04.04 | A1301.04.04 | CR002 |
| 139 | Cryo1.04.04.07.03.05 | Refrigeration Syst Mu2e Transfer Lines Checkout | 10d | 2014-08-07 A | 2014-08-20 A | 132FS+5d | 100% | 2014-07-18 | 2014-07-31 | 10d | FNAD_CRYO_TECH [200%]; FNAD_CRYO_EN [15%] | 172h | 172h | 5,457.68 | 5,457.68 | 5,457.68 |  |  | A1301.04.04 - Cryo Refrigerator System | 2910 | Cryo1.04.04 | A1301.04.04 | CR002 |
| 140 | Cryo1.04.04.07.04 | **Refrigeration Syst g-2/Cradle** | 140d | 2013-10-01 A | 2014-04-23 A |  | 100% | 2013-10-01 | 2014-04-28 | 143d |  | 404h | 404h | 82,913.36 | 82,913.36 | 82,913.36 |  |  |  |  |  |  |  |
| 141 | Cryo1.04.04.07.04.01 | Refrigeration Syst g-2/Cradle Procurement | 61d | 2013-10-01 A | 2013-12-30 A | 5 | 100% | 2013-10-01 | 2014-03-26 | 120d | FNAD_CRYO_TECH [1.6%]; FN_MS_STND_FY13 | 8h | 8h | 30,247.12 | 30,232 | 30,247.12 |  |  | A1301.04.04 - Cryo Refrigerator System | 2863 | Cryo1.04.04 | A1301.04.04 |  |
| 142 | Cryo1.04.04.07.04.02 | Refrigeration Syst g-2/Cradle Fabrication | 41d | 2013-10-29 A | 2013-12-30 A | 141SS+20d | 100% | 2013-10-29 | 2014-01-29 | 60d | FNAD_CRYO_TECH [181.8%]; FNAD_CRYO_EN [13.6%]; FN_MS_STND_FY13 | 344h | 344h | 30,915.36 | 30,511.68 | 30,915.36 |  |  | A1301.04.04 - Cryo Refrigerator System | 2864 | Cryo1.04.04 | A1301.04.04 |  |
| 143 | Cryo1.04.04.07.04.03 | Refrigeration Syst g-2/Cradle Installation/Rigging | 5d | 2014-04-10 A | 2014-04-16 A | 142, 15 | 100% | 2014-04-15 | 2014-04-21 | 5d | FNAD_CRYO_TECH; FNAD_CRYO_EN [20%]; FN_MS_STND_FY13 | 48h | 48h | 21,579.12 | 21,579.12 | 21,579.12 |  |  | A1301.04.04 - Cryo Refrigerator System | 2865 | Cryo1.04.04 | A1301.04.04 | CR002 |
| 144 | Cryo1.04.04.07.04.04 | Refrigeration Syst g-2/Cradle Checkout | 5d | 2014-04-17 A | 2014-04-23 A | 143 | 100% | 2014-04-22 | 2014-04-28 | 5d | FNAD_CRYO_EN [10%] | 4h | 4h | 171.76 | 171.76 | 171.76 |  |  | A1301.04.04 - Cryo Refrigerator System | 2866 | Cryo1.04.04 | A1301.04.04 |  |

| ID | WBS | Task | Type | Duration | Start | Finish | Predecessors | Complete | Baseline start | Baseline finish | Baseline duration | Constraint | Resources | Work | Actual work | Cost | Baseline cost | Actual cost | CTC + Name | Cobra WP ID | Cobra WBS # | CTC | CR# | BOE File Name | BOE Number |
| --- | --- | --- | --- | --- | --- | --- | --- | --- | --- | --- | --- | --- | --- | --- | --- | --- | --- | --- | --- | --- | --- | --- | --- | --- | --- |
| 145 | Cryo1.04.04.07.05 | **Refrigeration Syst g-2 Test Box** |  | 148d | 2014-02-03 A | 2014-08-29 A |  | 100% | 2014-02-03 | 2014-05-20 | 77d |  |  | 568h | 568h | 22,818.32 | 22,818.32 | 22,818.32 |  |  |  |  |  |  |  |
| 146 | Cryo1.04.04.07.05.01 | Refrigeration Syst g-2 Test Box Basic Design |  | 20d | 2014-02-03 A | 2014-02-28 A | 5FS+82d | 100% | 2014-02-03 | 2014-02-28 | 20d |  | FNAD_CRYO_EN [25%]; FNAD_MECH_DRAFTER [50%] | 120h | 120h | 4,028 | 4,028 | 4,028 | A1301.04.04 - Cryo Refrigerator System | 2868 | Cryo1.04.04 | A1301.04.04 |  |  |  |
| 147 | Cryo1.04.04.07.05.02 | Refrigeration Syst g-2 Test Box Detail Design |  | 15d | 2014-03-03 A | 2014-03-21 A | 146 | 100% | 2014-03-03 | 2014-03-21 | 15d |  | FNAD_MECH_DRAFTER | 120h | 120h | 3,465.6 | 3,465.6 | 3,465.6 | A1301.04.04 - Cryo Refrigerator System | 2869 | Cryo1.04.04 | A1301.04.04 |  |  |  |
| 148 | Cryo1.04.04.07.05.03 | Refrigeration Syst g-2 Test Box Procurement |  | 10d | 2014-03-10 A | 2014-03-21 A | 147FF | 100% | 2014-03-10 | 2014-03-21 | 10d |  | FNAD_CRYO_TECH; FNAD_CRYO_EN [20%]; FN_MS_STND_FY13 [500000%] | 96h | 96h | 8,158.24 | 8,158.24 | 8,158.24 | A1301.04.04 - Cryo Refrigerator System | 2870 | Cryo1.04.04 | A1301.04.04 | CR002 |  |  |
| 149 | Cryo1.04.04.07.05.04 | Refrigeration Syst g-2 Test Box Fabrication |  | 15d | 2014-03-10 A | 2014-03-28 A | 148FF+5d | 100% | 2014-03-17 | 2014-04-04 | 15d |  | FNAD_CRYO_TECH | 120h | 120h | 3,706.8 | 3,706.8 | 3,706.8 | A1301.04.04 - Cryo Refrigerator System | 2871 | Cryo1.04.04 | A1301.04.04 | CR002 |  |  |
| 150 | Cryo1.04.04.07.05.05 | Refrigeration Syst g-2 Test Box Installation |  | 65d | 2014-05-30 A | 2014-08-29 A | 149, 137 | 100% | 2014-05-12 | 2014-05-20 | 7d |  | FNAD_CRYO_TECH [21.5%] | 112h | 112h | 3,459.68 | 3,459.68 | 3,459.68 | A1301.04.04 - Cryo Refrigerator System | 2872 | Cryo1.04.04 | A1301.04.04 | CR002 |  |  |
| 151 | Cryo1.04.04.07.06 | Refrigeration Syst Safety Documents |  | 64d | 2014-06-03 A | 2014-09-02 A | 5FS+167d | 100% | 2014-06-03 | 2014-09-02 | 64d |  | FNAD_CRYO_EN [18.8%] | 96h | 96h | 4,122.24 | 4,122.24 | 4,122.24 | A1301.04.04 - Cryo Refrigerator System | 2875 | Cryo1.04.04 | A1301.04.04 |  |  |  |
| 152 | Cryo1.04.04.07.07 | Design Mu2e Transfer Line Bayonet Can |  | 123d | 2014-10-01 A | 2015-03-31 A | 6 | 100% | 2014-10-01 | 2015-04-07 | 128d |  | FNAD_MECH_DRAFTER [50.8%] | 500h | 500h | 14,440 | 14,440 | 14,440 | A1301.04.04 - Cryo Refrigerator System | 2825 | Cryo1.04.04 | A1301.04.04 |  | +Cryo Refrigeration System BOE | Beams 4395 |
| 153 | Cryo1.04.04.07.08 | Dwgs Ready for Mu2e Transfer Line Bayonet Can ** Deleted ** | milestone | 0d | 2015-03-31 A | 2015-03-31 A | 152 | 100% | 2015-03-31 | 2015-03-31 | 0d |  |  |  |  |  |  |  |  |  |  |  | CR013 |  |  |
| 154 | Cryo1.04.04.07.09 | Prep Req & Process PO for Mu2e Transfer Line Bayonet Can ** Deleted ** |  | 1d | 2015-03-31 A | 2015-03-31 A | 153FF | 100% | 2015-03-02 | 2015-03-31 | 1d |  |  |  |  |  |  |  | A1301.04.04 - Cryo Refrigerator System | 2827 | Cryo1.04.04 | A1301.04.04 | CR013 | +Cryo Refrigeration System BOE | Beams 4395 |
| 155 | Cryo1.04.04.07.10 | Award PO for Mu2e Transfer Line Bayonet Can ** Deleted ** |  | 1d | 2015-03-31 A | 2015-03-31 A | 154FF | 100% | 2015-03-31 | 2015-03-31 | 1d |  |  |  |  |  |  |  | A1301.04.04 - Cryo Refrigerator System | 2828 | Cryo1.04.04 | A1301.04.04 | CR013 | +Cryo Refrigeration System BOE | Beams 4395 |
| 156 | Cryo1.04.04.07.11 | Procured Items Delivered for Mu2e Transfer Line Bayonet Can ** Deleted ** |  | 1d | 2015-03-31 A | 2015-03-31 A | 155FF | 100% | 2015-03-02 | 2015-03-31 | 1d |  |  |  |  |  |  |  | A1301.04.04 - Cryo Refrigerator System | 2829 | Cryo1.04.04 | A1301.04.04 | CR013 | +Cryo Refrigeration System BOE | Beams 4395 |
| 157 | Cryo1.04.04.07.12 | Bayonet Cans Installed for Mu2e Transfer Line Bayonet Can ** Deleted ** |  | 1d | 2015-03-31 A | 2015-03-31 A | 156FF | 100% | 2015-03-02 | 2015-03-31 | 1d |  |  |  |  |  |  |  | A1301.04.04 - Cryo Refrigerator System | 2830 | Cryo1.04.04 | A1301.04.04 | CR013 | +Cryo Refrigeration System BOE | Beams 4395 |
| 158 | Cryo1.04.04.08 | **Strainer** |  | 69d | 2014-08-21 A | 2014-11-26 A |  | 100% | 2014-08-07 | 2014-11-14 | 0d |  |  |  |  | 43,423 |  | 43,423 |  |  |  |  |  |  |  |
| 159 | Cryo1.04.04.08.01 | Prep Req & Process PO for Strainer |  | 10d | 2014-08-21 A | 2014-09-04 A | 5FS+223d | 100% | 2014-08-07 | 2014-08-20 | 10d |  |  |  |  |  |  |  |  |  | Cryo1.04.04 |  | CR007 |  |  |
| 160 | Cryo1.04.04.08.02 | Award PO for Strainer |  | 1d | 2014-09-05 A | 2014-09-05 A | 159 | 100% | 2014-08-21 | 2014-08-21 | 1d |  |  |  |  |  |  |  | A1301.04.04 - Cryo Refrigerator System | 2927 | Cryo1.04.04 | A1301.04.04 | CR007 |  |  |
| 161 | Cryo1.04.04.08.03 | Deliver & Install Strainer |  | 8d | 2014-11-17 A | 2014-11-26 A | 160FS+50d | 100% | 2014-11-03 | 2014-11-14 | 10d |  | FN_MS_STND_FY13 |  |  | 43,423 | 44,248 | 43,423 | A1301.04.04 - Cryo Refrigerator System | 2928 | Cryo1.04.04 | A1301.04.04 | CR007 |  |  |
| 162 | Cryo1.04.04.09 | Cryo Refrigeration System Complete | milestone | 0d | 2015-03-31 A | 2015-03-31 A | 112, 144, 151, 128, 133, 209, 161FS+22d, 157 | 100% | 2014-12-26 | 2014-12-26 | 0d |  |  |  |  |  |  |  |  |  |  |  |  |  |  |
| 163 | Cryo1.04.05 | **Cryo Compressor System** |  | 261d | 2013-06-17 A | 2014-06-30 A |  | 100% | 2013-08-01 | 2014-09-23 | 320d |  |  | 1288h | 1288h | 283,452 | 283,452 | 283,452 |  |  | Cryo1.04.05 |  |  | +Cryo Compressor System BOE | Beams 4395 |
| 164 | Cryo1.04.05.01 | **Compressor System - T&M Work** |  | 248d | 2013-07-03 A | 2014-06-27 A |  | 100% | 2013-08-01 | 2014-09-02 | 293d |  |  | 120h | 120h | 31,067.6 | 31,067.6 | 31,067.6 |  |  |  |  |  | +Cryo Compressor System BOE | Beams 4395 |
| 165 | Cryo1.04.05.01.01 | Compressor Syst T&M - Award PO for Rigging T&M Work |  | 0.12d | 2013-07-03 A | 2013-07-03 A | 22FS+12d | 100% | 2013-08-01 | 2013-08-01 | 0.12d |  |  |  |  |  |  |  | A1301.04.05 - Cryo Compressor System | 2680 | Cryo1.04.05 | A1301.04.05 |  | +Cryo Compressor System BOE | Beams 4395 |
| 166 | Cryo1.04.05.01.02 | Compressor Syst - Rigging T&M |  | 2d | 2013-07-29 A | 2013-07-30 A | 165 | 100% | 2013-08-01 | 2013-08-01 | 2d | start no earlier than 2013-07-29 | FNAD_CRYO_TECH [62.5%]; FN_MS_STND_FY13 [569000%] | 10h | 10h | 5,979.7 | 5,980 | 5,979.7 | A1301.04.05 - Cryo Compressor System | 2794 | Cryo1.04.05 | A1301.04.05 |  |  |  |
| 167 | Cryo1.04.05.01.03 | Compressor Syst T&M - Award PO for Electrical T&M Work |  | 1d | 2014-02-27 A | 2014-02-27 A | 5FS+100d | 100% | 2014-02-27 | 2014-02-27 | 1d |  |  |  |  |  |  |  | A1301.04.05 - Cryo Compressor System | 2806 | Cryo1.04.05 | A1301.04.05 |  | +Cryo Compressor System BOE | Beams 4395 |
| 168 | Cryo1.04.05.01.04 | Compressor Syst - T&M |  | 65d | 2014-03-28 A | 2014-06-27 A | 167FS+20d | 100% | 2014-02-28 | 2014-09-02 | 130d |  | FNAD_CRYO_TECH [21.2%]; FN_MS_STND_FY13 | 110h | 110h | 25,087.9 | 25,087.9 | 25,087.9 | A1301.04.05 - Cryo Compressor System | 1161 | Cryo1.04.05 | A1301.04.05 |  | +Cryo Compressor System BOE | Beams 4395 |
| 169 | Cryo1.04.05.01.05 | Compressor System - T&M Work Complete | milestone | 0d | 2014-06-27 A | 2014-06-27 A | 168, 166 | 100% | 2014-09-02 | 2014-09-02 | 0d |  |  |  |  |  |  |  |  |  | Cryo1.04.05 |  |  |  |  |

| ID | WBS | Task | Type | Duration | Start | Finish | Predecessors | Complete | Baseline start | Baseline finish | Baseline duration | Constraint | Resources | Work | Actual work | Cost | Baseline cost | Actual cost | BOE File Name | BOE Number | Text20 | CTC + Name | Cobra WP ID | Cobra WBS # | CTC | CR# |
| --- | --- | --- | --- | --- | --- | --- | --- | --- | --- | --- | --- | --- | --- | --- | --- | --- | --- | --- | --- | --- | --- | --- | --- | --- | --- | --- |
| 170 | Cryo1.04.05.02 | **Water System Valves & Refurbishment** |  | 62.12d | 2013-06-17 A | 2013-09-13 A |  | 100% | 2013-08-01 | 2013-09-13 | 62.12d |  |  | 8h | 8h | 40,231.76 | 40,231.76 | 40,231.76 | +Cryo Compressor System BOE | Beams 4395 | Need to detail the procurement. |  |  |  |  |  |
| 171 | Cryo1.04.05.02.01 | Prep Req & Process PO for Water System Valves |  | 42d | 2013-06-17 A | 2013-08-14 A | 22 | 100% | 2013-08-01 | 2013-08-14 | 42d |  | FNAD_CRYO_TECH [2.4%] | 8h | 8h | 231.76 | 232 | 231.76 | +Cryo Compressor System BOE | Beams 4395 |  | A1301.04.05 - Cryo Compressor System | 2590 | Cryo1.04.05 | A1301.04.05 |  |
| 172 | Cryo1.04.05.02.02 | Water System Valves Award |  | 0.12d | 2013-08-15 A | 2013-08-15 A | 171 | 100% | 2013-08-15 | 2013-08-15 | 0.12d |  |  |  |  |  |  |  | +Cryo Compressor System BOE | Beams 4395 |  | A1301.04.05 - Cryo Compressor System | 2591 | Cryo1.04.05 | A1301.04.05 |  |
| 173 | Cryo1.04.05.02.03 | Water System Valves Delivery |  | 15d | 2013-08-22 A | 2013-09-13 A | 172FS+5d | 100% | 2013-08-23 | 2013-09-13 | 15d |  | FN_MS_STND_FY13 |  |  | 17,000 | 17,000 | 17,000 | +Cryo Compressor System BOE | Beams 4395 |  | A1301.04.05 - Cryo Compressor System | 2592 | Cryo1.04.05 | A1301.04.05 |  |
| 174 | Cryo1.04.05.02.04 | Account Payback for items purchased before Project Plan approved |  | 1d | 2013-07-01 A | 2013-07-01 A |  | 100% | 2013-08-01 | 2013-08-01 | 20d | start no earlier than 2013-07-01 | FN_MS_STND_FY13 |  |  | 23,000 | 23,000 | 23,000 |  |  |  | A1301.04.05 - Cryo Compressor System | 2898 | Cryo1.04.05 | A1301.04.05 |  |
| 175 | Cryo1.04.05.03 | Compressor Syst Paint vessels & base |  | 20d | 2014-05-01 A | 2014-05-29 A | 5FS+145d | 100% | 2014-02-27 | 2014-09-23 | 146d |  | FNAD_CRYO_TECH [50%]; FN_MS_STND_FY13 | 80h | 80h | 42,471.2 | 42,471.2 | 42,471.2 | +Cryo Compressor System BOE | Beams 4395 | Successor? | A1301.04.05 - Cryo Compressor System | 858 | Cryo1.04.05 | A1301.04.05 |  |
| 176 | Cryo1.04.05.04 | Compressor Syst Electrical |  | 140d | 2013-10-09 A | 2014-05-01 A | 22FS+80d | 100% | 2013-10-09 | 2014-05-01 | 140d | start no earlier than 2013-02-01 | FNAD_CRYO_TECH [7.1%] | 80h | 80h | 2,471.2 | 2,320 | 2,471.2 | +Cryo Compressor System BOE | Beams 4395 | Need predecessor | A1301.04.05 - Cryo Compressor System | 855 | Cryo1.04.05 | A1301.04.05 |  |
| 177 | Cryo1.04.05.05 | Compressor Syst Electrical Complete | milestone | 0d | 2014-05-01 A | 2014-05-01 A | 176, 215 | 100% | 2014-05-01 | 2014-05-01 | 0d |  |  |  |  |  |  |  |  |  |  |  |  |  |  |  |
| 178 | Cryo1.04.05.06 | Compressor Syst Controls |  | 181d | 2013-10-09 A | 2014-06-30 A | 22FS+80d | 100% | 2013-10-09 | 2014-05-01 | 140d |  | FNAD_CRYO_TECH [27.6%] | 400h | 400h | 12,356 | 11,600 | 12,356 | +Cryo Compressor System BOE | Beams 4395 | Successor? | A1301.04.05 - Cryo Compressor System | 856 | Cryo1.04.05 | A1301.04.05 |  |
| 179 | Cryo1.04.05.07 | Compressor Syst Controls Complete | milestone | 0d | 2014-06-30 A | 2014-06-30 A | 178 | 100% | 2014-05-01 | 2014-05-01 | 0d |  |  |  |  |  |  |  |  |  |  |  |  |  |  |  |
| 180 | Cryo1.04.05.08 | **Cryo Compressor System Heat Exchangers** |  | 202d | 2013-08-09 A | 2014-05-30 A |  | 100% | 2013-08-09 | 2014-06-19 | 216d |  |  | 600h | 600h | 154,854.24 | 154,854.24 | 154,854.24 |  |  |  |  |  |  |  |  |
| 181 | Cryo1.04.05.08.01 | Prep Paperwork & Obtain Approval for Sole Source for Heat Exchangers (5) |  | 20d | 2013-08-09 A | 2013-09-06 A | 22FS+38d | 100% | 2013-08-09 | 2013-09-06 | 20d |  | FNAD_CRYO_EN [5%] | 8h | 8h | 410.56 | 410.56 | 410.56 |  |  |  | A1301.04.05 - Cryo Compressor System | 2810 | Cryo1.04.05 | A1301.04.05 |  |
| 182 | Cryo1.04.05.08.02 | Release Order for Heat Exchangers (5) |  | 0.12d | 2013-09-09 A | 2013-09-09 A | 181 | 100% | 2013-09-09 | 2013-09-09 | 0.12d |  |  |  |  |  |  |  | +Cryo Compressor System BOE | Beams 4395 |  | A1301.04.05 - Cryo Compressor System | 2811 | Cryo1.04.05 | A1301.04.05 |  |
| 183 | Cryo1.04.05.08.03 | Dwgs to Fermi for Approval for Heat Exchangers (5) | milestone | 0d | 2013-10-10 A | 2013-10-10 A | 182FS+23d | 100% | 2013-10-10 | 2013-10-10 | 0d |  |  |  |  |  |  |  |  |  |  |  |  |  |  |  |
| 184 | Cryo1.04.05.08.04 | Approval of Dwgs by Fermi for Heat Exchangers (5) |  | 10d | 2013-10-11 A | 2013-10-24 A | 183 | 100% | 2013-10-11 | 2013-10-24 | 10d |  | FNAD_CRYO_EN | 80h | 80h | 3,435.2 | 4,105.6 | 3,435.2 |  |  |  | A1301.04.05 - Cryo Compressor System | 2814 | Cryo1.04.05 | A1301.04.05 |  |
| 185 | Cryo1.04.05.08.05 | Receive & Examine Heat Exchangers (5) |  | 1d | 2014-01-16 A | 2014-01-16 A | 184FS+53d | 100% | 2014-02-06 | 2014-02-06 | 1d |  | FNAD_CRYO_EN [200%]; FNAD_CRYO_TECH [400%]; FN_MS_STND_FY13 | 48h | 48h | 136,675.52 | 136,749.12 | 136,675.52 |  |  |  | A1301.04.05 - Cryo Compressor System | 2812 | Cryo1.04.05 | A1301.04.05 |  |
| 186 | Cryo1.04.05.08.06 | Move Heat Exchanders to A0 |  | 10d | 2014-01-17 A | 2014-01-31 A | 185 | 100% | 2014-02-07 | 2014-02-07 | 1d |  | FNAD_CRYO_TECH [20%] | 16h | 16h | 494.24 | 464 | 494.24 |  |  |  | A1301.04.05 - Cryo Compressor System | 2793 | Cryo1.04.05 | A1301.04.05 |  |
| 187 | Cryo1.04.05.08.07 | Replace A0 Heat Exchangers |  | 24d | 2014-04-28 A | 2014-05-30 A | 186FS+60d | 100% | 2014-04-28 | 2014-06-05 | 28d |  | FNAD_CRYO_TECH [233.3%] | 448h | 448h | 13,838.72 | 13,838.72 | 13,838.72 |  |  |  | A1301.04.05 - Cryo Compressor System | 2815 | Cryo1.04.05 | A1301.04.05 |  |
| 188 | Cryo1.04.05.08.08 | Complete Heat Exchangers Installation | milestone | 0d | 2014-05-30 A | 2014-05-30 A | 187 | 100% | 2014-06-19 | 2014-06-19 | 0d |  |  |  |  |  |  |  |  |  |  |  |  |  |  |  |
| 189 | Cryo1.04.06 | **Cryo Interconnect Piping** |  | 211d | 2013-07-26 A | 2014-05-29 A |  | 100% | 2013-08-01 | 2014-07-30 | 254d |  |  | 2542h | 2542h | 459,834.93 | 516,424.18 | 459,834.93 | +Cryo Interconnect Piping BOE | Beams 4395 |  |  |  | Cryo1.04.06 |  |  |
| 190 | Cryo1.04.06.01 | Interconnect Piping Prep Purch Req & Process PO for all work |  | 20d | 2013-07-26 A | 2013-08-22 A | 22FS+28d | 100% | 2013-08-01 | 2013-08-22 | 20d |  | FNAD_CRYO_EN [78.8%] | 126h | 126h | 6,466.32 | 6,466.32 | 6,466.32 | +Cryo Interconnect Piping BOE | Beams 4395 |  | A1301.04.06 - Cryo Interconnect Piping | 2687 | Cryo1.04.06 | A1301.04.06 |  |
| 191 | Cryo1.04.06.02 | Interconnect Piping Award A0 to MC-1 Suction & Discharge Pipe |  | 1d | 2013-08-23 A | 2013-08-23 A | 190 | 100% | 2013-08-23 | 2013-08-23 | 1d |  |  |  |  |  |  |  | +Cryo Interconnect Piping BOE | Beams 4395 |  | A1301.04.06 - Cryo Interconnect Piping | 2690 | Cryo1.04.06 | A1301.04.06 |  |
| 192 | Cryo1.04.06.03 | Interconnect Piping Deliver & Install A0 to MC-1 Suction & Discharge Pipe |  | 10d | 2013-09-17 A | 2013-09-30 A | 191FS+15d | 100% | 2013-09-17 | 2013-09-30 | 10d |  | FN_MS_STND_FY13 |  |  | 76,678 | 76,678 | 76,678 | +Cryo Interconnect Piping BOE | Beams 4395 |  | A1301.04.06 - Cryo Interconnect Piping | 2691 | Cryo1.04.06 | A1301.04.06 |  |
| 193 | Cryo1.04.06.04 | Interconnect Piping Award Misc FY13 |  | 0.12d | 2013-08-23 A | 2013-08-23 A | 190 | 100% | 2013-08-23 | 2013-09-04 | 0.12d |  |  |  |  |  |  |  | +Cryo Interconnect Piping BOE | Beams 4395 |  | A1301.04.06 - Cryo Interconnect Piping | 2886 | Cryo1.04.06 | A1301.04.06 |  |
| 194 | Cryo1.04.06.05 | Interconnect Piping Award Misc FY14 |  | 0.12d | 2013-10-01 A | 2013-10-01 A | 5 | 100% | 2013-10-01 | 2013-10-01 | 0.12d |  |  |  |  |  |  |  | +Cryo Interconnect Piping BOE | Beams 4395 |  | A1301.04.06 - Cryo Interconnect Piping | 2897 | Cryo1.04.06 | A1301.04.06 |  |
| 195 | Cryo1.04.06.06 | Interconnect Piping Deliver Misc |  | 50d | 2013-08-23 A | 2013-11-04 A | 193, 194FF+20d | 100% | 2013-09-05 | 2013-11-13 | 50d |  | FN_MS_STND_FY13 |  |  | 110,000 | 110,000 | 110,000 | +Cryo Interconnect Piping BOE | Beams 4395 |  | A1301.04.06 - Cryo Interconnect Piping | 2887 | Cryo1.04.06 | A1301.04.06 |  |
| 196 | Cryo1.04.06.07 | Interconnect Piping Award Tank Farm Headers |  | 0.12d | 2013-10-01 A | 2013-10-01 A | 190, 5 | 100% | 2013-10-01 | 2013-10-01 | 0.12d |  |  |  |  |  |  |  | +Cryo Interconnect Piping BOE | Beams 4395 |  | A1301.04.06 - Cryo Interconnect Piping | 2768 | Cryo1.04.06 | A1301.04.06 |  |
| 197 | Cryo1.04.06.08 | Interconnect Piping Deliver & Install Farm Headers |  | 50d | 2013-10-22 A | 2014-01-08 A | 196FS+15d | 100% | 2013-10-22 | 2014-01-08 | 50d |  | FN_MS_STND_FY13 |  |  | 29,872 | 29,872 | 29,872 | +Cryo Interconnect Piping BOE | Beams 4395 |  | A1301.04.06 - Cryo Interconnect Piping | 2767 | Cryo1.04.06 | A1301.04.06 |  |
| 198 | Cryo1.04.06.09 | Interconnect Piping Award PO for Parts for MC-1 Bldg Header |  | 23d | 2013-10-07 A | 2013-11-06 A | 190FS+30d | 100% | 2013-10-07 | 2013-12-03 | 23d |  |  |  |  |  |  |  | +Cryo Interconnect Piping BOE | Beams 4395 |  | A1301.04.06 - Cryo Interconnect Piping | 2883 | Cryo1.04.06 | A1301.04.06 |  |
| 199 | Cryo1.04.06.10 | Interconnect Piping Deliver Parts for MC-1 Bldg Header |  | 38d | 2013-10-07 A | 2013-11-27 A | 198SS | 100% | 2013-10-07 | 2014-01-28 | 38d | finish no earlier than 2013-11-27 | FN_MS_STND_FY13 |  |  | 15,000 | 15,000 | 15,000 | +Cryo Interconnect Piping BOE | Beams 4395 |  | A1301.04.06 - Cryo Interconnect Piping | 2884 | Cryo1.04.06 | A1301.04.06 |  |
| 200 | Cryo1.04.06.11 | OS of Interconnect piping - A0 to MC-1 Discharge & Suction Header |  | 165d | 2013-08-01 A | 2014-03-31 A | 199FF, 22FS+32d | 100% | 2013-08-01 | 2014-07-30 | 250d |  | FNAD_CRYO_TECH [118.2%]; FNAD_CRYO_EN [46.7%] | 2176h | 2176h | 75,191.01 | 76,853.12 | 75,191.01 | +Cryo Interconnect Piping BOE | Beams 4395 | Is there a procurement cycle? Need predecessor | A1301.04.06 - Cryo Interconnect Piping | 2692 | Cryo1.04.06 | A1301.04.06 |  |
| 201 | Cryo1.04.06.12 | Account Payback for items purchased before Project Plan approved |  | 1d | 2013-08-01 A | 2013-08-01 A |  | 100% | 2013-08-01 | 2013-08-30 | 22d | start no earlier than 2013-08-01 | FN_MS_STND_FY13 |  |  | 16,114 | 16,114 | 16,114 | +Cryo Interconnect Piping BOE | Beams 4395 |  | A1301.04.06 - Cryo Interconnect Piping | 2888 | Cryo1.04.06 | A1301.04.06 |  |
| 202 | Cryo1.04.06.13 | Interconnect Piping Underground Connection to MC-1 |  | 24d | 2013-10-01 A | 2013-11-01 A | 5 | 100% | 2013-10-01 | 2013-11-01 | 24d | start no earlier than 2013-09-09 | FNAD_CRYO_TECH [20.8%]; FN_MS_STND_FY13 | 40h | 40h | 31,235.6 | 31,160 | 31,235.6 | +Cryo Interconnect Piping BOE | Beams 4395 |  | A1301.04.06 - Cryo Interconnect Piping | 2822 | Cryo1.04.06 | A1301.04.06 |  |
| 203 | Cryo1.04.06.14 | Install Experimental Hall Pipes on Stands |  | 5d | 2014-04-10 A | 2014-04-16 A | 15 | 100% | 2014-04-15 | 2014-04-21 | 5d |  | FNAD_CRYO_TECH | 40h | 40h | 1,235.6 | 1,235.6 | 1,235.6 |  |  |  | A1301.04.06 - Cryo Interconnect Piping | 2916 | Cryo1.04.06 | A1301.04.06 | CR002 |
| 204 | Cryo1.04.06.15 | Interconnect Piping Award MC-1 Refrig Bldg Headers |  | 10d | 2014-03-10 A | 2014-03-21 A | 190FS+133d | 100% | 2014-03-10 | 2014-03-21 | 10d |  |  |  |  |  |  |  | +Cryo Interconnect Piping BOE | Beams 4395 |  | A1301.04.06 - Cryo Interconnect Piping | 2766 | Cryo1.04.06 | A1301.04.06 |  |
| 205 | Cryo1.04.06.16 | Interconnect Piping Contractor Install MC-1 Refrig Bldg Headers |  | 25d | 2014-03-24 A | 2014-04-25 A | 204, 13, 202, 14 | 100% | 2014-03-24 | 2014-04-25 | 25d |  | FN_MS_STND_FY13 |  |  | 48,300 | 48,300 | 48,300 | +Cryo Interconnect Piping BOE | Beams 4395 |  | A1301.04.06 - Cryo Interconnect Piping | 2765 | Cryo1.04.06 | A1301.04.06 | CR002 |
| 206 | Cryo1.04.06.17 | Interconnect Piping Award MC-1 Exp Hall Headers |  | 1d | 2014-04-23 A | 2014-04-23 A | 190FS+165d | 100% | 2014-04-23 | 2014-04-23 | 1d |  |  |  |  |  |  |  |  |  |  | A1301.04.06 - Cryo Interconnect Piping | 2911 | Cryo1.04.06 | A1301.04.06 | CR004 |
| 207 | Cryo1.04.06.18 | Interconnect Piping Contractor Install MC-1 Exp Hall Headers |  | 25d | 2014-04-24 A | 2014-05-29 A | 206, 203 | 100% | 2014-04-24 | 2014-05-29 | 25d |  | FN_MS_STND_FY13 |  |  | 36,400 | 101,573 | 36,400 |  |  |  | A1301.04.06 - Cryo Interconnect Piping | 2912 | Cryo1.04.06 | A1301.04.06 | CR002, CR004 |
| 208 | Cryo1.04.06.19 | Additional connection to the nitrogen header in support of g-2 |  | 20d | 2014-05-01 A | 2014-05-29 A | 207FF | 100% | 2014-05-01 | 2014-05-29 | 0d |  | FN_MS_STND_FY13 [840000%] |  |  | 8,400 |  | 8,400 |  |  |  | A1301.04.06 - Cryo Interconnect Piping | 2918 | Cryo1.04.06 | A1301.04.06 | CR005 |
| 209 | Cryo1.04.06.20 | Refrig Syst Interconnect Piping - Installation Complete | milestone | 0d | 2014-05-29 A | 2014-05-29 A | 192, 197, 200, 70, 195, 210, 211 | 100% | 2014-07-30 | 2014-07-30 | 0d |  |  |  |  |  |  |  |  |  |  |  |  |  |  |  |
| 210 | Cryo1.04.06.21 | Interconnect Piping Installation Oversight MC-1 Refrig Bldg Headers |  | 25d | 2014-03-24 A | 2014-04-25 A | 205FF | 100% | 2014-02-10 | 2014-04-25 | 55d |  | FNAD_CRYO_TECH [55%] | 110h | 110h | 3,397.9 | 3,397.9 | 3,397.9 |  |  |  | A1301.04.06 - Cryo Interconnect Piping | 2914 | Cryo1.04.06 | A1301.04.06 | CR002 |
| 211 | Cryo1.04.06.22 | Interconnect Piping Installation Oversight MC-1 Exp Hall Headers |  | 25d | 2014-04-24 A | 2014-05-29 A | 207FF | 100% | 2014-05-08 | 2014-06-12 | 25d |  | FNAD_CRYO_TECH [25%] | 50h | 50h | 1,544.5 | 1,544.5 | 1,544.5 |  |  |  | A1301.04.06 - Cryo Interconnect Piping | 2915 | Cryo1.04.06 | A1301.04.06 | CR002 |

Notes:
- 200: Includes 300 hours of pipefitter @$90/hour = $27000

| ID | WBS | Task | Type | Duration | Start | Finish | Predecessors | Complete | Remaining | Baseline start | Baseline finish | Baseline duration | Total slack | Free slack | Constraint | Resources | Work | Actual work | Cost | Baseline cost | Actual cost | BOE File Name | BOE Number | Cobra WBS # | Text20 | CTC + Name | Cobra WP ID | CTC | CR# |
| --- | --- | --- | --- | --- | --- | --- | --- | --- | --- | --- | --- | --- | --- | --- | --- | --- | --- | --- | --- | --- | --- | --- | --- | --- | --- | --- | --- | --- | --- |
| 212 | Cryo1.04.07 | **Cryo Interconnect Electrical & Controls** |  | 282d | 2013-06-17 A | 2014-07-30 A |  | 100% |  | 2013-08-01 | 2014-05-23 | 236d |  |  |  |  | 880h | 880h | 91,553.2 | 91,553.15 | 91,553.2 | +Cryo Interconnect Elect & Controls BOE | Beams 4395 | Cryo1.04.07 | Successor? |  |  |  |  |
| 213 | Cryo1.04.07.01 | Procure Compressor System Controls |  | 1d | 2013-06-17 A | 2013-06-17 A | 22 | 100% |  | 2013-08-01 | 2013-08-01 | 20d |  |  |  | FN_MS_STND_FY13 |  |  | 37,700 | 37,700 | 37,700 |  |  | Cryo1.04.07 |  | A1301.04.07 - Cryo Interconnect Electrical & Controls | 2893 | A1301.04.07 |  |
| 214 | Cryo1.04.07.02 | Procure Xgallery Fiber Connection |  | 24d | 2013-11-19 A | 2013-12-26 A | 5FS+35d | 100% |  | 2013-11-19 | 2013-12-26 | 24d |  |  |  | FNAD_CRYO_TECH [8.3%]; FN_MS_STND_FY13 | 16h | 16h | 17,164.24 | 17,134 | 17,164.24 | +Cryo Interconnect Elect & Controls BOE | Beams 4395 | Cryo1.04.07 |  | A1301.04.07 - Cryo Interconnect Electrical & Controls | 2695 | A1301.04.07 |  |
| 215 | Cryo1.04.07.03 | Run Fiber Cable between A0 & MC-1 |  | 43d | 2013-12-27 A | 2014-02-28 A | 214, 213 | 100% |  | 2013-12-27 | 2014-03-10 | 49d |  |  |  | FNAD_CRYO_TECH [18.6%]; FN_MS_STND_FY13 | 64h | 64h | 11,976.96 | 11,856 | 11,976.96 | +Cryo Interconnect Elect & Controls BOE | Beams 4395 | Cryo1.04.07 |  | A1301.04.07 - Cryo Interconnect Electrical & Controls | 2696 | A1301.04.07 |  |
| 216 | Cryo1.04.07.04 | Interconnect Electrical & Controls Engineering |  | 208d | 2013-10-01 A | 2014-07-30 A | 5 | 100% |  | 2013-10-01 | 2014-05-23 | 162d |  |  |  | FNAD_CRYO_TECH [48.1%] | 800h | 800h | 24,712 | 23,200 | 24,712 | +Cryo Interconnect Elect & Controls BOE | Beams 4395 | Cryo1.04.07 |  | A1301.04.07 - Cryo Interconnect Electrical & Controls | 2697 | A1301.04.07 |  |
| 217 | Cryo1.04.08 | **Cryogenic Fluids** |  | 248d | 2015-03-05 A | 2016-03-01 A |  | 100% |  | 2015-03-04 | 2015-06-24 | 19d |  |  |  |  | 32h | 32h | 203,630.48 | 150,000 | 203,630.48 |  |  | Cryo1.04.08 |  |  |  |  |  |
| 218 | Cryo1.04.08.01 | Purchase Helium for Mu2e |  | 1d | 2015-03-05 A | 2015-03-05 A |  | 100% |  | 2015-03-04 | 2015-03-04 | 1d |  |  | start no earlier than 2015-03-05 |  |  |  |  |  |  |  |  |  |  |  |  |  | CR012 |
| 219 | Cryo1.04.08.02 | Receive 1st Helium Delivery |  | 1d | 2015-03-13 A | 2015-03-13 A | 218FS+5d | 100% |  | 2015-03-12 | 2015-03-12 | 1d |  |  |  | FN_MS_STND_FY13 |  |  | 48,248 | 50,000 | 48,248 |  |  | Cryo1.04.08 |  | A1301.04.08 - Cryogenic Fluids | 2932 | A1301.04.08 | CR012 |
| 220 | Cryo1.04.08.03 | Receive 2nd Helium Delivery |  | 1d | 2015-04-13 A | 2015-04-13 A | 219FS+20d | 100% |  | 2015-03-20 | 2015-03-20 | 1d |  |  |  | FN_MS_STND_FY13 |  |  | 48,248 | 50,000 | 48,248 |  |  | Cryo1.04.08 |  | A1301.04.08 - Cryogenic Fluids | 2933 | A1301.04.08 | CR012 |
| 221 | Cryo1.04.08.04 | Receive 3rd Helium Delivery |  | 35d | 2015-06-11 A | 2015-07-30 A | 220FF+10d | 100% |  | 2015-03-30 | 2015-03-30 | 1d |  |  | finish no earlier than 2015-07-30 | FN_MS_STND_FY13 |  |  | 48,248 | 50,000 | 48,248 |  |  | Cryo1.04.08 |  | A1301.04.08 - Cryogenic Fluids | 2934 | A1301.04.08 | CR012 |
| 222 | Cryo1.04.08.05 | Certify 2 Trailers/Connect 2 Trailers & Pump/Backfill |  | 102d | 2015-10-01 A | 2016-03-01 A | 221 | 100% |  | 2015-04-01 | 2015-06-24 | 0d |  |  | start no earlier than 2015-10-01 | FNPD_CRYO_TECH [3.9%]; FN_MS_STND_FY13 | 32h | 32h | 58,886.48 |  | 58,886.48 |  |  | Cryo1.04.08 |  | A1301.04.08 - Cryogenic Fluids | 2935 | A1301.04.08 | CR012, CR014 |
| 223 | Cryo1.05 | **Cryo Experiment interfaces** |  | 949d | 2013-08-19 A | 2017-06-01 |  | 95% | 47.75d | 2013-08-19 | 2016-11-17 | 902d | 39d |  |  |  | 7236h | 6979.37h | 605,923.74 | 876,227.4 | 575,983.51 |  |  | Cryo1.05 |  |  |  |  |  |
| 224 | Cryo1.05.01 | **Mu2e Interface Connection** |  | 759d | 2014-05-22 A | 2017-06-01 |  | 95% | 38.8d | 2014-05-22 | 2016-11-17 | 712d | 39d |  |  |  | 7066h | 6809.37h | 597,199.34 | 867,503 | 567,259.11 | +Cryo Mu2e Interface Connection BOE | Beams 4395 | Cryo1.05.01 |  |  |  |  |  |
| 225 | Cryo1.05.01.01 | Mu2e Interface - Basic Engineering |  | 40d | 2014-05-22 A | 2014-07-18 A | 5FS+160d | 100% |  | 2014-05-22 | 2014-07-18 | 40d |  |  |  | FNAD_CRYO_EN [75%] | 240h | 240h | 10,305.6 | 10,305.6 | 10,305.6 | +Cryo Mu2e Interface Connection BOE | Beams 4395 | Cryo1.05.01 |  | A1301.05.01 - Mu2e Interface Connection | 2698 | A1301.05.01 |  |
| 226 | Cryo1.05.01.02 | Mu2e Interface - Basic Engineering Complete | milestone | 0d | 2014-07-18 A | 2014-07-18 A | 225 | 100% |  | 2014-07-18 | 2014-07-18 | 0d |  |  |  |  |  |  |  |  |  |  |  |  |  |  |  |  |  |
| 227 | Cryo1.05.01.03 | Mu2e Interface - Detailed Engineering |  | 117d | 2014-10-08 A | 2015-03-30 A | 226 | 100% |  | 2014-07-21 | 2014-12-10 | 100d |  |  | start no earlier than 2014-10-08 | FNAD_CRYO_EN [59.8%] | 560h | 560h | 24,046.4 | 24,046.4 | 24,046.4 | +Cryo Mu2e Interface Connection BOE | Beams 4395 | Cryo1.05.01 |  | A1301.05.01 - Mu2e Interface Connection | 2700 | A1301.05.01 |  |
| 228 | Cryo1.05.01.04 | Mu2e Interface - Design/Drafting ** Deleted ** |  | 1d | 2015-03-31 A | 2015-03-31 A | 227 | 100% |  | 2014-12-11 | 2015-03-31 | 80d |  |  |  |  |  |  |  | 86,447.96 |  | +Cryo Mu2e Interface Connection BOE | Beams 4395 | Cryo1.05.01 |  | A1301.05.01 - Mu2e Interface Connection | 2701 | A1301.05.01 | CR013 |
| 229 | Cryo1.05.01.05 | Mu2e Interface - Transfer Line System Design |  | 333d | 2015-04-20 A | 2016-08-15 A | 225 | 100% |  | 2015-03-31 | 2015-08-19 | 0d |  |  | start no earlier than 2015-04-20 | FNTD_CRYO_DESIGNER [36.7%]; FNPD_CRYO_EN [23.4%]; FNAD_MECH_ASMBY_TECH [4.2%]; FN_MS_STND_FY13 | 1712h | 1712h | 85,622.58 |  | 85,622.58 |  |  | Cryo1.05.01 |  | A1301.05.01 - Mu2e Interface Connection | 2988 | A1301.05.01 | CR013 |
| 230 | Cryo1.05.01.06 | Mu2e Interface - Transfer Line Drawings Ready | milestone | 0d | 2016-08-15 A | 2016-08-15 A | 228, 229 | 100% |  | 2015-08-19 | 2015-08-19 | 0d |  |  |  |  |  |  |  |  |  |  |  |  |  |  |  |  | CR013 |
| 231 | Cryo1.05.01.07 | Mu2e Interface - Prep Req & Process PO for Parts ** Deleted ** |  | 1d | 2015-03-02 A | 2015-03-02 A |  | 100% |  | 2015-03-02 | 2015-03-31 | 1d |  |  | start no earlier than 2015-03-02 |  |  |  |  |  |  | +Cryo Mu2e Interface Connection BOE | Beams 4395 | Cryo1.05.01 |  | A1301.05.01 - Mu2e Interface Connection | 2606 | A1301.05.01 | CR013 |
| 232 | Cryo1.05.01.08 | Mu2e Interface - 1st Award PO ** Deleted ** |  | 1d | 2015-03-03 A | 2015-03-03 A | 231 | 100% |  | 2015-03-31 | 2015-03-31 | 1d |  |  |  |  |  |  |  |  |  | +Cryo Mu2e Interface Connection BOE | Beams 4395 | Cryo1.05.01 |  | A1301.05.01 - Mu2e Interface Connection | 2607 | A1301.05.01 | CR013 |
| 233 | Cryo1.05.01.09 | Mu2e Interface - 1st Procured Items Delivered ** Deleted ** |  | 1d | 2015-03-04 A | 2015-03-04 A | 232 | 100% |  | 2015-03-31 | 2015-03-31 | 1d |  |  |  |  |  |  |  |  |  | +Cryo Mu2e Interface Connection BOE | Beams 4395 | Cryo1.05.01 |  | A1301.05.01 - Mu2e Interface Connection | 2608 | A1301.05.01 | CR013 |
| 234 | Cryo1.05.01.10 | Mu2e Interface - 2nd Award PO ** Deleted ** |  | 1d | 2015-03-02 A | 2015-03-02 A |  | 100% |  | 2015-03-31 | 2015-03-31 | 1d |  |  | start no earlier than 2015-03-02 |  |  |  |  |  |  | +Cryo Mu2e Interface Connection BOE | Beams 4395 | Cryo1.05.01 |  | A1301.05.01 - Mu2e Interface Connection | 2834 | A1301.05.01 | CR013 |
| 235 | Cryo1.05.01.11 | Mu2e Interface - 2nd Procured Items Delivered ** Deleted ** |  | 1d | 2015-03-03 A | 2015-03-03 A | 234 | 100% |  | 2015-03-31 | 2015-03-31 | 1d |  |  |  |  |  |  |  |  |  |  |  | Cryo1.05.01 |  | A1301.05.01 - Mu2e Interface Connection | 2833 | A1301.05.01 | CR013 |
| 236 | Cryo1.05.01.12 | Mu2e Interface - Fabrication ** Deleted ** |  | 1d | 2015-03-05 A | 2015-03-05 A | 233, 235FF | 100% |  | 2015-03-31 | 2015-03-31 | 1d |  |  |  |  |  |  |  |  |  | +Cryo Mu2e Interface Connection BOE | Beams 4395 | Cryo1.05.01 |  | A1301.05.01 - Mu2e Interface Connection | 2739 | A1301.05.01 | CR013 |
| 237 | Cryo1.05.01.13 | Mu2e Interface - Installation ** Deleted ** |  | 1d | 2015-03-06 A | 2015-03-06 A | 236 | 100% |  | 2015-03-31 | 2015-03-31 | 1d |  |  |  |  |  |  |  |  |  | +Cryo Mu2e Interface Connection BOE | Beams 4395 | Cryo1.05.01 |  | A1301.05.01 - Mu2e Interface Connection | 2714 | A1301.05.01 | CR013 |
| 238 | Cryo1.05.01.14 | Mu2e Interface - Task Management ** Deleted ** |  | 1d | 2015-03-06 A | 2015-03-06 A | 237SS | 100% |  | 2015-03-31 | 2015-03-31 | 1d |  |  |  |  |  |  |  |  |  | +Cryo Mu2e Interface Connection BOE | Beams 4395 | Cryo1.05.01 |  | A1301.05.01 - Mu2e Interface Connection | 2738 | A1301.05.01 | CR013 |
| 239 | Cryo1.05.01.15 | Mu2e Interface - Transport of Existing Lines |  | 50d | 2015-08-20 A | 2015-10-30 A | 230FF+20d | 100% |  | 2015-08-20 | 2015-11-13 | 60d |  |  |  | FNPD_CRYO_EN [12%]; FNPD_MECH_ASMBY_TECH [172.5%]; FNTD_WELDER [22.5%]; FN_MS_STND_FY13 | 828h | 828h | 58,887.72 | 60,222.6 | 58,887.72 |  |  | Cryo1.05.01 |  | A1301.05.01 - Mu2e Interface Connection | 2978 | A1301.05.01 | CR014 |
| 240 | Cryo1.05.01.16 | Mu2e Interface - Assemble Other Components |  | 386d | 2015-11-16 A | 2017-06-01 | 239FS+10d | 93% | 27.02d | 2015-11-16 | 2016-05-10 | 120d | 0d |  |  | FNPD_CRYO_EN [2.9%]; FNPD_MECH_ASMBY_TECH [11.7%]; FN_MS_STND_FY13 | 450h | 418.5h | 230,729 | 242,828.4 | 214,577.97 |  |  | Cryo1.05.01 |  | A1301.05.01 - Mu2e Interface Connection | 2979 | A1301.05.01 | CR014 |
| 241 | Cryo1.05.01.17 | Mu2e Interface - Install Helium Gas Lines between MC-1 and MC-2 |  | 210d | 2016-08-01 A | 2017-06-01 |  | 95% | 10.5d | 2016-07-28 | 2016-10-31 | 0d | 39d | 0d | start no earlier than 2016-08-01 | FNPD_CRYO_EN [2.7%]; FNPD_CRYO_TECH [35.7%] | 645h | 612.75h | 40,466.3 |  | 38,442.99 |  |  | Cryo1.05.01 |  | A1301.05.01 - Mu2e Interface Connection | 3010 | A1301.05.01 | CR019 |
| 242 | Cryo1.05.01.18 | Mu2e Interface - Assemble/Install Transfer Line |  | 196d | 2016-08-19 A | 2017-06-01 | 239, 240FF, 20FF | 90% | 19.6d | 2016-06-01 | 2016-08-24 | 60d | 0d |  |  | FNTD_CRYO_DESIGNER [7.7%]; FNPD_CRYO_EN [3.8%]; FNPD_MECH_ASMBY_TECH [57.4%]; FNTD_WELDER [28.7%]; FN_MS_STND_FY13 | 1530h | 1377h | 100,917.2 | 102,670.8 | 90,825.48 |  |  | Cryo1.05.01 |  | A1301.05.01 - Mu2e Interface Connection | 2980 | A1301.05.01 | CR014 |
| 243 | Cryo1.05.01.19 | Mu2e Interface - Transfer Line Testing |  | 166d | 2016-10-03 A | 2017-06-01 | 242FF | 88% | 19.92d | 2016-08-25 | 2016-11-17 | 60d | 0d |  | start no earlier than 2016-10-03 | FNPD_CRYO_EN [35.9%]; FNPD_MECH_ASMBY_TECH [123.2%]; FNTD_WELDER [37.5%] | 1101h | 1061.12h | 46,224.54 | 46,236.6 | 44,550.37 |  |  | Cryo1.05.01 |  | A1301.05.01 - Mu2e Interface Connection | 2981 | A1301.05.01 | CR014 |
| 244 | Cryo1.05.01.20 | Mu2e is connected | milestone | 0d | 2017-06-01 | 2017-06-01 | 237, 238, 243 |  |  | 2016-11-17 | 2016-11-17 | 0d | 0d |  |  |  |  |  |  |  |  |  |  |  | Successor? |  |  |  | CR013 |
| 245 | Cryo1.05.02 | g-2 Interface Connection |  | 24d | 2013-08-19 A | 2013-09-20 A |  | 100% |  | 2013-08-19 | 2013-09-20 | 24d |  |  | start no earlier than 2013-08-19 | FNAD_CRYO_EN [88.5%] | 170h | 170h | 8,724.4 | 8,724.4 | 8,724.4 | +Cryo Mu2e Interface Connection BOE | Beams 4395 | Cryo1.05.02 |  | A1301.05.02 - g-2 Interface Connection | 2881 | A1301.05.02 |  |
| 246 | Cryo1.06 | Cryo Safety Documents |  | 231d | 2013-10-01 A | 2014-09-02 A | 62FF | 100% |  | 2013-10-01 | 2014-09-02 | 231d |  |  |  | FNAD_CRYO_EN [63.2%] | 1168h | 1168h | 50,153.92 | 59,941.76 | 50,153.92 | Cryo Safety Documents BOE | Beams 4395 | Cryo1.06 |  | A1301.06 - Cryo Safety Documents | 1126 | A1301.06 |  |

Notes:
- 215: Electrician @99 hours X $101/hour = $10,000.

| ID | WBS | Task | Type | Duration | Start | Finish | Predecessors | Complete | Remaining | Baseline start | Baseline finish | Baseline duration | Total slack | Free slack | Constraint | Resources | Work | Actual work | Cost | Baseline cost | Actual cost | Misc | Cobra WBS # | BOE File Name | BOE Number | CTC + Name | Cobra WP ID | CTC | CR# | Text20 |
| --- | --- | --- | --- | --- | --- | --- | --- | --- | --- | --- | --- | --- | --- | --- | --- | --- | --- | --- | --- | --- | --- | --- | --- | --- | --- | --- | --- | --- | --- | --- |
| 247 | Cryo1.07 | **Testing/Checkout** |  | 693d | 2014-10-22 A | 2017-07-28 |  | 17% | 577.5d | 2014-10-31 | 2017-05-22 | 639d | 0d |  |  |  | 1240h | 620h | 44,569.6 | 44,569.6 | 22,284.8 | ***Charge Code*** | Cryo1.07 |  |  |  |  |  |  |  |
| 248 | Cryo1.07.01 | g-2 Cryo Checkout |  | 8d | 2014-10-22 A | 2014-10-31 A | 25 | 100% |  | 2014-10-31 | 2015-01-02 | 40d |  |  |  | FNAD_CRYO_EN [406.2%]; FNAD_CRYO_TECH [562.5%] | 620h | 620h | 22,284.8 | 22,284.8 | 22,284.8 |  | Cryo1.07 | Cryo Testing_Checkout BOE | Beams 4395 | A1301.07 - Testing/Checkout | 1131 | A1301.07 |  |  |
| 249 | Cryo1.07.02 | Mu2e Cryo Checkout |  | 40d | 2017-06-02 | 2017-07-28 | 244 |  |  | 2017-03-28 | 2017-05-22 | 40d | 0d |  |  | FNPD_CRYO_EN [81.2%]; FNPD_CRYO_TECH [112.5%] | 620h |  | 22,284.8 | 22,284.8 |  |  | Cryo1.07 | Cryo Testing_Checkout BOE | Beams 4395 | A1301.07 - Testing/Checkout | 2824 | A1301.07 | CR014 |  |
| 250 | Cryo1.07.03 | Mu2e ORC | milestone | 0d | 2017-07-28 | 2017-07-28 | 249 |  |  | 2017-05-22 | 2017-05-22 | 0d | 0d |  |  |  |  |  |  |  |  |  |  |  |  |  |  |  |  |  |
| 251 | Cryo1.07.04 | g-2 ORC | milestone | 0d | 2014-11-14 A | 2014-11-14 A | 248FS+10d | 100% |  | 2015-01-02 | 2015-01-02 | 0d |  |  |  |  |  |  |  |  |  |  |  |  |  |  |  |  |  |  |
| 252 | Cryo1.08 | Cryo g-2 Acceptance Tests |  | 20d | 2014-09-24 A | 2014-10-21 A | 106FF+15d, 68 | 100% |  | 2014-09-29 | 2014-10-24 | 20d |  |  |  | FNAD_CRYO_EN [151.9%]; FNAD_CRYO_TECH [276.9%]; FN_MS_STND_FY13 | 686h | 686h | 57,717.69 | 57,717.69 | 57,717.69 | ***Charge Code*** | Cryo1.08 | Cryo g-2 Acceptance Tests BOE | Beams 4395 | A1301.08 - Cryo g-2 Acceptance Tests | 1134 | A1301.08 |  | Successor? Labor? |
| 253 | Cryo1.09 | **Mu2e Acceptance Tests** |  | 20d | 2017-06-02 | 2017-06-29 |  |  |  | 2016-11-18 | 2016-12-19 | 0d | 20d |  |  |  | 686h |  | 40,918.69 |  |  |  |  |  |  |  |  |  |  |  |
| 254 | Cryo1.09.01 | Cryo Mu2e Acceptance Tests |  | 20d | 2017-06-02 | 2017-06-29 | 244 |  |  | 2016-11-18 | 2016-12-19 | 20d | 20d | 0d |  | FNTD_CRYO_EN [151.9%]; FNPD_CRYO_TECH [276.9%]; FN_MS_STND_FY13 | 686h |  | 40,918.69 | 40,918.69 |  |  | Cryo1.09 | Cryo Mu2e Acceptance Tests BOE | Beams 4395 | A1301.09 - Cryo Mu2e Acceptance Tests | 2611 | A1301.09 | CR014 |  |
| 255 | Cryo1.10 | **Cryo Distribution Box (CDB)** |  | 572d | 2015-04-15 A | 2017-07-25 |  | 77% | 129.45d | 2015-04-15 | 2017-04-14 | 513d | 3d |  |  |  | 5299h | 4088h | 1,377,974.02 | 1,490,678.02 | 932,970.97 |  |  |  |  |  |  |  |  |  |
| 256 | Cryo1.10.01 | **CDB Preliminary Design Phase** |  | 197d | 2015-04-15 A | 2016-01-29 A |  | 100% |  | 2015-04-15 | 2015-07-23 | 70d |  |  |  |  | 1396h | 1396h | 57,747.04 | 57,747.04 | 57,747.04 |  |  |  |  |  |  |  |  |  |
| 257 | Cryo1.10.01.01 | Cryo Distribution Box Requirements |  | 15d | 2015-04-15 A | 2015-05-05 A |  | 100% |  | 2015-04-15 | 2015-04-21 | 5d |  |  | start no earlier than 2015-04-15 | FNTD_CRYO_DESIGNER [22.5%]; FNTD_CRYO_EN [110.8%] | 160h | 160h | 6,643.6 | 6,643.6 | 6,643.6 |  | Cryo1.10 |  |  | A1301.10 Cryo Distribution Box (CDB) | 2939 | A1301.10 | CR013 |  |
| 258 | Cryo1.10.01.02 | Preliminary Specification |  | 15d | 2015-04-15 A | 2015-05-05 A | 257FF | 100% |  | 2015-04-22 | 2015-05-12 | 15d |  |  |  | FNPD_CRYO_SR [16.7%]; FNTD_PRJ_MNGR [16.7%] | 40h | 40h | 2,365.8 | 2,365.8 | 2,365.8 |  | Cryo1.10 |  |  | A1301.10 Cryo Distribution Box (CDB) | 2940 | A1301.10 | CR013 |  |
| 259 | Cryo1.10.01.03 | Preliminary Drawings |  | 15d | 2015-04-15 A | 2015-05-05 A | 257FF | 100% |  | 2015-04-22 | 2015-05-12 | 15d |  |  |  | FNTD_CRYO_DESIGNER [20%]; FNTD_CRYO_EN [20%] | 48h | 48h | 1,859.52 | 1,859.52 | 1,859.52 |  | Cryo1.10 |  |  | A1301.10 Cryo Distribution Box (CDB) | 2941 | A1301.10 | CR013 |  |
| 260 | Cryo1.10.01.04 | Review of Packet |  | 10d | 2015-05-06 A | 2015-05-19 A | 258, 259 | 100% |  | 2015-05-13 | 2015-05-27 | 10d |  |  |  | FNTD_CRYO_EN [10%]; FNTD_CRYO_DESIGNER [30%]; FNTD_PRJ_MNGR [10%] | 40h | 40h | 1,640.88 | 1,640.88 | 1,640.88 |  | Cryo1.10 |  |  | A1301.10 Cryo Distribution Box (CDB) | 2942 | A1301.10 | CR013 |  |
| 261 | Cryo1.10.01.05 | Conduct & Evaluate RFI |  | 20d | 2015-05-20 A | 2015-06-17 A | 260 | 100% |  | 2015-05-28 | 2015-06-24 | 20d |  |  |  | FNPD_CRYO_SR [10%]; FNTD_CRYO_EN [10%]; FNTD_FABRCATN_SPCLST [5%]; FNTD_PRJ_MNGR [5%] | 48h | 48h | 2,433.84 | 2,433.84 | 2,433.84 |  | Cryo1.10 |  |  | A1301.10 Cryo Distribution Box (CDB) | 2943 | A1301.10 | CR013 |  |
| 262 | Cryo1.10.01.06 | Final decision on procurement plan |  | 1d | 2015-06-18 A | 2015-06-18 A | 261 | 100% |  | 2015-06-25 | 2015-06-25 | 1d |  |  |  |  |  |  |  |  |  |  |  |  |  |  |  |  | CR013 |  |
| 263 | Cryo1.10.01.07 | Complete CDB Prelim. Eng. Design |  | 197d | 2015-04-15 A | 2016-01-29 A | 257SS | 100% |  | 2015-04-15 | 2015-07-23 | 70d |  |  |  | FNTD_CRYO_EN [33.6%]; FNTD_MECH_DESIGN_EN [5.1%]; FNTD_MECH_DESIGNER [25.4%]; FNAD_MECH_ASMBY_TECH [3.2%] | 1060h | 1060h | 42,803.4 | 42,803.4 | 42,803.4 |  | Cryo1.10 |  |  | A1301.10 Cryo Distribution Box (CDB) | 2945 | A1301.10 | CR013 |  |
| 264 | Cryo1.10.02 | **CDB Procurement Readiness** |  | 157d | 2015-06-11 A | 2016-01-29 A |  | 100% |  | 2015-07-24 | 2015-10-05 | 50d |  |  |  |  | 1231h | 1231h | 51,023.04 | 51,023.04 | 51,023.04 |  |  |  |  |  |  |  |  |  |
| 265 | Cryo1.10.02.01 | Complete Final Specification |  | 157d | 2015-06-11 A | 2016-01-29 A | 263FF+23d | 100% |  | 2015-07-24 | 2015-09-03 | 30d |  |  |  | FNTD_CRYO_EN [41.9%]; FNTD_MECH_DESIGN_EN [7.2%]; FNTD_MECH_DESIGNER [25.9%]; FNAD_MECH_ASMBY_TECH [4%] | 991h | 991h | 40,422.04 | 40,422.04 | 40,422.04 |  | Cryo1.10 |  |  | A1301.10 Cryo Distribution Box (CDB) | 2949 | A1301.10 | CR013 |  |
| 266 | Cryo1.10.02.02 | Complete Drawings for Procurement |  | 109d | 2015-08-19 A | 2016-01-29 A | 263FF+28d | 100% |  | 2015-07-24 | 2015-09-03 | 30d |  |  |  | FNTD_MECH_DESIGNER [13.8%]; FNTD_MECH_DESIGN_EN [4.6%] | 160h | 160h | 6,365.6 | 6,365.6 | 6,365.6 |  | Cryo1.10 |  |  | A1301.10 Cryo Distribution Box (CDB) | 2948 | A1301.10 | CR013 |  |
| 267 | Cryo1.10.02.03 | Complete Documentation for Procurement Package |  | 30d | 2015-12-14 A | 2016-01-29 A | 266FF | 100% |  | 2015-09-04 | 2015-09-21 | 10d |  |  |  |  |  |  |  |  |  |  |  |  |  |  |  |  | CR013 |  |
| 268 | Cryo1.10.02.04 | Final review of package |  | 10d | 2016-01-15 A | 2016-01-29 A | 267FF | 100% |  | 2015-09-22 | 2015-10-05 | 10d |  |  |  | FNPD_CRYO_SR [25%]; FNTD_CRYO_EN [25%]; FNTD_MECH_DESIGN_EN [25%]; FNTD_PRJ_MNGR [25%] | 80h | 80h | 4,235.4 | 4,235.4 | 4,235.4 |  | Cryo1.10 |  |  | A1301.10 Cryo Distribution Box (CDB) | 2946 | A1301.10 | CR013 |  |
| 269 | Cryo1.10.03 | **Procurement and Fabrication of CDB** |  | 374d | 2016-02-01 A | 2017-07-24 |  | 73% | 100.08d | 2015-10-06 | 2017-04-14 | 346d | 3d |  |  |  | 1375h | 1022.4h | 931,609.88 | 1,077,001.88 | 616,015.67 |  |  |  |  |  |  |  |  |  |
| 270 | Cryo1.10.03.01 | CDB Bid Cycle |  | 21d | 2016-02-01 A | 2016-02-29 A | 268 | 100% |  | 2015-10-06 | 2015-11-16 | 30d |  |  |  | FNPD_CRYO_SR [11.9%]; FNTD_CRYO_EN [11.9%]; FNTD_PRJ_MNGR [11.9%] | 60h | 60h | 3,224.6 | 3,224.6 | 3,224.6 |  | Cryo1.10 |  |  | A1301.10 Cryo Distribution Box (CDB) | 2961 | A1301.10 | CR013 |  |
| 271 | Cryo1.10.03.02 | Evaluate Bid/choose vendor |  | 9d | 2016-04-28 A | 2016-05-10 A | 270FS+42d | 100% |  | 2015-11-17 | 2015-11-23 | 5d |  |  |  | FNPD_CRYO_SR [11.1%]; FNTD_CRYO_EN [11.1%]; FNTD_MECH_DESIGN_EN [11.1%]; FNTD_PRJ_MNGR [11.1%] | 32h | 32h | 1,694.16 | 1,694.16 | 1,694.16 |  | Cryo1.10 |  |  | A1301.10 Cryo Distribution Box (CDB) | 2960 | A1301.10 | CR013 |  |
| 272 | Cryo1.10.03.03 | Project and DOE approval |  | 5d | 2016-05-11 A | 2016-05-17 A | 271 | 100% |  | 2015-11-24 | 2016-01-12 | 30d |  |  |  |  |  |  |  |  |  |  |  |  |  |  |  |  | CR013 |  |
| 273 | Cryo1.10.03.04 | Contract signed for CDB | milestone | 0d | 2016-05-23 A | 2016-05-23 A | 272FS+4d | 100% |  | 2016-01-12 | 2016-01-12 | 0d |  |  |  |  |  |  |  |  |  |  |  |  |  |  |  |  | CR013 |  |
| 274 | Cryo1.10.03.05 | Fermilab Oversight of CDB |  | 215d | 2016-05-24 A | 2017-04-03 | 273 | 80% | 43d | 2016-01-13 | 2017-02-22 | 224d | 81d | 78d |  | FNTD_MECH_DESIGNER [9.3%]; FNTD_CRYO_EN [25.6%]; FNTD_MECH_ASMBY_TECH [32.7%] | 1163h | 930.4h | 41,823.32 | 41,823.32 | 33,458.66 |  | Cryo1.10 |  |  | A1301.10 Cryo Distribution Box (CDB) | 2955 | A1301.10 | CR014 |  |
| 275 | Cryo1.10.03.06 | Kickoff Meeting |  | 1d | 2016-06-13 A | 2016-06-13 A | 273FS+13d, 291, 290 | 100% |  | 2016-06-13 | 2016-06-13 | 1d |  |  |  |  |  |  |  |  |  |  |  |  |  |  |  |  | CR017 |  |
| 276 | Cryo1.10.03.07 | Vendor Order Weka Valves |  | 1d | 2016-06-22 A | 2016-06-22 A | 275FS+6d | 100% |  | 2016-06-22 | 2016-06-22 | 1d |  |  |  | FN_MS_STND_FY13 |  |  | 124,005 | 124,005 | 124,005 |  | Cryo1.10 |  |  | A1301.10 Cryo Distribution Box (CDB) | 2995 | A1301.10 | CR017 |  |
| 277 | Cryo1.10.03.08 | Vendor Submit Design and Fermi Approval |  | 1d | 2016-08-19 A | 2016-08-19 A | 276FS+40d | 100% |  | 2016-08-19 | 2016-08-19 | 1d |  |  |  | FN_MS_STND_FY13 |  |  | 330,680 | 330,680 | 330,680 |  | Cryo1.10 |  |  | A1301.10 Cryo Distribution Box (CDB) | 2996 | A1301.10 | CR017 |  |
| 278 | Cryo1.10.03.09 | Design Improvements/Upgrades |  | 86d | 2016-11-28 A | 2017-04-03 |  | 75% | 21.5d | 2016-11-28 | 2017-01-12 | 0d | 3d | 0d | start no earlier than 2016-11-28 |  |  |  | 53,711 |  | 40,283.25 |  | Cryo1.10 |  |  | A1301.10 Cryo Distribution Box (CDB) | 3011 | A1301.10 | CR021 |  |
| 279 | Cryo1.10.03.10 | Vendor Compl Vessel Code Stmp, Theral Shld Compnts, Trace Tube |  | 30d | 2017-02-21 A | 2017-04-03 | 277FS+53d, 278FF | 50% | 15d | 2016-11-04 | 2016-11-04 | 1d | 3d | 0d |  | FN_MS_STND_FY13 |  |  | 165,340 | 165,340 | 82,670 |  | Cryo1.10 |  |  | A1301.10 Cryo Distribution Box (CDB) | 2997 | A1301.10 | CR017 |  |
| 280 | Cryo1.10.03.11 | Vendor Compl Piping Spool Subassemblies |  | 1d | 2017-04-27 | 2017-04-27 | 279FS+17d |  |  | 2016-12-02 | 2016-12-02 | 1d | 3d | 0d |  | FN_MS_STND_FY13 |  |  | 82,670 | 82,670 |  |  | Cryo1.10 |  |  | A1301.10 Cryo Distribution Box (CDB) | 2998 | A1301.10 | CR017 |  |
| 281 | Cryo1.10.03.12 | Vendor Ship CDB to Fermilab |  | 1d | 2017-06-16 | 2017-06-16 | 280FS+34d |  |  | 2017-03-10 | 2017-03-10 | 1d | 3d | 0d |  |  |  |  |  |  |  |  |  |  |  |  |  |  | CR013, CR017 |  |
| 282 | Cryo1.10.03.13 | Fermi Perform safety review of CDB |  | 10d | 2017-06-19 | 2017-06-30 | 281 |  |  | 2017-03-13 | 2017-03-24 | 10d | 3d | 0d |  |  |  |  |  |  |  |  |  |  |  |  |  |  | CR013, CR017 |  |
| 283 | Cryo1.10.03.14 | Acceptance tests at Fermilab |  | 14d | 2017-07-03 | 2017-07-21 | 282 |  |  | 2017-03-27 | 2017-04-13 | 14d | 3d | 0d |  | FNTD_MECH_DESIGN_EN [35.7%]; FNTD_MECH_ASMBY_TECH [71.4%] | 120h |  | 4,456.8 | 4,456.8 |  |  | Cryo1.10 |  |  | A1301.10 Cryo Distribution Box (CDB) | 2952 | A1301.10 | CR014, CR017 |  |
| 284 | Cryo1.10.03.15 | CDB received and accepted |  | 1d | 2017-07-24 | 2017-07-24 | 283, 274FF |  |  | 2017-04-14 | 2017-04-14 | 1d | 3d | 0d |  | FN_MS_STND_FY13 |  |  | 124,005 | 124,005 |  |  | Cryo1.10 |  |  | A1301.10 Cryo Distribution Box (CDB) | 2951 | A1301.10 | CR013, CR017 |  |
| 285 | Cryo1.10.03.16 | Vendor completed final design and drawings ** Delete ** |  | 1d | 2016-05-02 A | 2016-05-02 A |  | 100% |  | 2016-01-13 | 2016-05-18 | 90d |  |  | start no earlier than 2016-05-02 |  |  |  |  |  |  |  |  |  |  |  |  |  | CR013, CR017 |  |
| 286 | Cryo1.10.03.17 | Vendor fabricates CDB ** Delete ** |  | 1d | 2016-05-02 A | 2016-05-02 A |  | 100% |  | 2016-05-19 | 2017-01-25 | 170d |  |  | start no earlier than 2016-05-02 |  |  |  |  |  |  |  |  |  |  |  |  |  | CR013, CR017 |  |

| ID | WBS | Task | Type | Duration | Start | Finish | Predecessors | Complete | Remaining | Baseline start | Baseline finish | Baseline duration | Total slack | Free slack | Constraint | Resources | Work | Actual work | Cost | Baseline cost | Actual cost | CTC + Name | Cobra WP ID | Cobra WBS # | CTC | CR# | Text20 |
| --- | --- | --- | --- | --- | --- | --- | --- | --- | --- | --- | --- | --- | --- | --- | --- | --- | --- | --- | --- | --- | --- | --- | --- | --- | --- | --- | --- |
| 287 | Cryo1.10.04 | **Ancillary Components** |  | 572d | 2015-04-15 A | 2017-07-25 |  | 70% | 172.86d | 2015-04-15 | 2017-04-06 | 523d | 3d |  |  |  | 1297h | 438.6h | 337,594.06 | 304,906.06 | 208,185.22 |  |  |  |  |  |  |
| 288 | Cryo1.10.04.01 | Specify Helium Dewar |  | 242d | 2015-04-15 A | 2016-04-01 A |  | 100% |  | 2015-04-15 | 2015-05-12 | 20d |  |  | start no earlier than 2015-04-15 | FNTD_CRYO_DESIGNER [0.4%]; FNTD_CRYO_EN [0.8%] | 24h | 24h | 963.36 | 963.36 | 963.36 | A1301.10 Cryo Distribution Box (CDB) | 2969 | Cryo1.10 | A1301.10 | CR013 |  |
| 289 | Cryo1.10.04.02 | Procure Helium dewar |  | 106d | 2016-09-27 A | 2017-03-02 |  | 40% | 63.6d | 2016-10-12 | 2017-01-11 | 60d | 3d | 0d | start no earlier than 2016-09-27 | FN_MS_STND_FY13 |  |  | 46,463 | 46,463 | 18,585.2 | A1301.10 Cryo Distribution Box (CDB) | 2968 | Cryo1.10 | A1301.10 | CR013 |  |
| 290 | Cryo1.10.04.03 | Procure Heat exchanger #1 |  | 186d | 2015-12-07 A | 2016-08-31 A | 8FS+45d | 100% |  | 2015-12-07 | 2016-06-06 | 125d |  |  |  | FNAD_CRYO_EN [6.7%]; FN_MS_STND_FY13 | 100h | 100h | 68,294 | 68,294 | 68,294 | A1301.10 Cryo Distribution Box (CDB) | 2967 | Cryo1.10 | A1301.10 | CR013, CR016 |  |
| 291 | Cryo1.10.04.04 | Procure Heat exchanger #2 |  | 248d | 2015-12-07 A | 2016-11-30 A | 8FS+45d | 100% |  | 2015-12-07 | 2016-06-06 | 125d |  |  |  | FNAD_CRYO_EN [5%]; FN_MS_STND_FY13 | 100h | 100h | 20,294 | 20,294 | 20,294 | A1301.10 Cryo Distribution Box (CDB) | 2993 | Cryo1.10 | A1301.10 | CR016 |  |
| 292 | Cryo1.10.04.05 | TL from Helium dewar to CDB |  | 138d | 2016-09-27 A | 2017-04-17 | 289SS | 20% | 110.4d | 2016-10-12 | 2017-01-11 | 60d | 72d |  |  | FN_MS_STND_FY13 |  |  | 23,232 | 23,232 | 4,646.4 | A1301.10 Cryo Distribution Box (CDB) | 2966 | Cryo1.10 | A1301.10 | CR013 |  |
| 293 | Cryo1.10.04.06 | TLs from CDB to feedbox |  | 229d | 2016-05-18 A | 2017-04-17 | 272FF+150d | 20% | 183.2d | 2016-01-13 | 2016-02-24 | 30d | 72d |  |  | FNTD_CRYO_DESIGNER [26.2%]; FNTD_CRYO_EN [14%]; FNTD_CRYO_TECH [17.5%]; FNTD_FABRCATN_SPCLST [0.9%]; FN_MS_STND_FY13 | 1073h | 214.6h | 65,083.7 | 65,227.7 | 13,016.74 | A1301.10 Cryo Distribution Box (CDB) | 2965 | Cryo1.10 | A1301.10 | CR014 |  |
| 294 | Cryo1.10.04.07 | Procure Transfer line A |  | 301d | 2016-01-25 A | 2017-04-03 |  | 87% | 39.13d | 2016-02-25 | 2016-05-18 | 60d | 82d |  |  | FN_MS_STND_FY13 |  |  | 94,696 | 94,696 | 82,385.52 | A1301.10 Cryo Distribution Box (CDB) | 2964 | Cryo1.10 | A1301.10 | CR013 |  |
| 295 | Cryo1.10.04.08 | Feedbox valves related to CDB |  | 60d | 2017-05-01 | 2017-07-25 | 289FS+41d |  |  | 2017-01-12 | 2017-04-06 | 60d | 3d |  |  | FN_MS_STND_FY13 |  |  | 18,568 | 18,568 |  | A1301.10 Cryo Distribution Box (CDB) | 2963 | Cryo1.10 | A1301.10 | CR013 |  |
| 296 | Cryo1.11 | Safety documents are completed | milestone | 0d | 2014-09-02 A | 2014-09-02 A | 246 | 100% |  | 2014-09-02 | 2014-09-02 | 0d |  |  |  |  |  |  |  |  |  |  |  |  |  |  | Successor? |
| 297 | Cryo1.12 | g-2 Checkout complete | milestone | 0d | 2014-10-31 A | 2014-10-31 A | 248, 252 | 100% |  | 2015-01-02 | 2015-01-02 | 0d |  |  |  |  |  |  |  |  |  |  |  |  |  |  | Successor? |
| 298 | Cryo1.13 | Mu2e Checkout complete | milestone | 0d | 2017-07-28 | 2017-07-28 | 254, 249 |  |  | 2017-01-23 | 2017-01-23 | 0d | 0d |  |  |  |  |  |  |  |  |  |  |  |  | CR013 |  |
| 299 | Cryo1.14 | **MC-1 Refrigerator Upgrades** |  | 164d | 2016-07-01 A | 2017-02-28 A |  | 100% |  | 2016-07-01 | 2016-12-01 | 125d |  |  |  |  | 2203h | 2203h | 123,684.42 | 124,500 | 123,684.42 |  |  |  |  |  |  |
| 300 | Cryo1.14.01 | Dampen noisy instrument signals in PLC |  | 121d | 2016-09-01 A | 2017-02-28 A |  | 100% |  | 2016-08-01 | 2016-09-30 | 44d |  |  | start no earlier than 2016-09-01 | FNPD_CRYO_EN [3.1%]; FNPD_CRYO_TECH [3.1%] | 60h | 60h | 2,214.9 | 1,476.6 | 2,214.9 |  | 3000 | Cryo1.14 | A1301.14 | CR018, CR019 |  |
| 301 | Cryo1.14.02 | Display all Mu2e Refrigerator Variables in iFIX |  | 44d | 2016-09-01 A | 2016-11-02 A |  | 100% |  | 2016-08-01 | 2016-09-30 | 44d |  |  | start no earlier than 2016-09-01 | FNPD_CRYO_EN [1.7%]; FNPD_CRYO_TECH [17%] | 66h | 66h | 2,111.04 | 1,407.36 | 2,111.04 |  | 3001 | Cryo1.14 | A1301.14 | CR018, CR019 |  |
| 302 | Cryo1.14.03 | Calib all Cryo Instrmts, incl Charg VPTs, Trans, Gauges, Check Calib on Thermometry, Flow Meters, etc. |  | 134d | 2016-08-15 A | 2017-02-28 A | 301FF+42d | 100% |  | 2016-08-01 | 2016-12-01 | 86d |  |  | start no earlier than 2016-08-15 | FNPD_CRYO_EN [6.7%]; FNPD_CRYO_TECH [40.8%] | 509h | 509h | 31,590.61 | 21,050.11 | 31,590.61 |  | 3002 | Cryo1.14 | A1301.14 | CR018, CR019 |  |
| 303 | Cryo1.14.04 | Inst Press Trace Cables for all Engines, Wired to an Oscill w/Select Switch |  | 121d | 2016-09-01 A | 2017-02-28 A |  | 100% |  | 2016-08-01 | 2016-09-30 | 44d |  |  | start no earlier than 2016-09-01 | FNPD_CRYO_EN [0.6%]; FNPD_CRYO_TECH [2.5%] | 30h | 30h | 3,999 | 2,666 | 3,999 |  | 3003 | Cryo1.14 | A1301.14 | CR018, CR019 |  |
| 304 | Cryo1.14.05 | Correct all Control Loops, Fix Feedback, Retune, 26 Loops for Compressors & One Refrig |  | 60d | 2016-11-30 A | 2017-02-28 A | 300FF, 301FF, 302FF | 100% |  | 2016-09-01 | 2016-12-01 | 63d |  |  |  | FNPD_CRYO_EN [73.1%]; FNPD_CRYO_TECH [109.8%] | 878h | 878h | 31,350.97 | 20,890.35 | 31,350.97 |  | 3004 | Cryo1.14 | A1301.14 | CR018, CR019 |  |
| 305 | Cryo1.14.06 | Instl Block & Bypass Valves for Purifier, Allow Temp Instl of Mobile Purifier |  | 86d | 2016-09-01 A | 2017-01-09 A |  | 100% |  | 2016-08-01 | 2016-12-01 | 86d |  |  | start no earlier than 2016-09-01 | FNPD_CRYO_EN [27.9%]; FNPD_CRYO_TECH [57.6%] | 588h | 588h | 42,976.92 | 28,651.28 | 42,976.92 |  | 3005 | Cryo1.14 | A1301.14 | CR018, CR019 |  |
| 306 | Cryo1.14.07 | Move Nitrogen Gas Pipe |  | 94d | 2016-08-29 A | 2017-01-17 A |  | 100% |  | 2016-09-01 | 2016-12-01 | 63d |  |  | start no earlier than 2016-08-29 | FNPD_CRYO_EN [2.4%]; FNPD_CRYO_TECH [4.8%] | 36h | 36h | 4,256.64 | 2,837.76 | 4,256.64 |  | 3006 | Cryo1.14 | A1301.14 | CR018, CR019 |  |
| 307 | Cryo1.14.08 | Instrument Air Pipeline |  | 144d | 2016-08-01 A | 2017-02-28 A |  | 100% |  | 2016-07-28 | 2016-10-31 | 67d |  |  | start no earlier than 2016-08-01 | FNPD_CRYO_EN [0.5%]; FNPD_CRYO_TECH [2.6%] | 36h | 36h | 5,184.34 | 2,789.56 | 5,184.34 |  | 3007 | Cryo1.14 | A1301.14 | CR018, CR019 |  |
| 308 | Cryo1.14.09 | Install Adjuster Nut on all Engine Valves *** Deleted *** |  | 20d | 2016-07-01 A | 2016-07-29 A |  | 100% |  | 2016-07-01 | 2016-07-29 | 20d |  |  | start no earlier than 2016-07-01 |  |  |  |  |  |  |  | 3008 | Cryo1.14 | A1301.14 | CR018, CR019 |  |
| 309 | Cryo1.14.10 | Replace all BC Valve Actuators *** Deleted *** |  | 20d | 2016-07-01 A | 2016-07-29 A |  | 100% |  | 2016-07-01 | 2016-07-29 | 61d |  |  | start no earlier than 2016-07-01 |  |  |  |  |  |  |  | 3009 | Cryo1.14 | A1301.14 | CR018, CR019 |  |

Notes:
- 304: Asume other fridges will be duplicates
